# Pixel_mechanics

Schedule from MS Project, 2000-10-02 to 2005-09-30, costs in $.
LBNL

## Calendars

- Standard: Mon-Fri 08:00-12:00, 13:00-17:00; Sat-Sun off.

## Resources

| Resource | Group | Rate |
| --- | --- | --- |
| LBLj SP PRJ | LBL | 67.53 |
| LBLj EE PRJ | LBL | 70.95 |
| LBLj ME PRJ | LBL | 70.95 |
| LBLj DS PRJ | LBL | 31.52 |
| LBLj ET PRJ | LBL | 31.52 |
| LBLj MT PRJ | LBL | 31.52 |
| LBLj AS PRJ | LBL | 30.01 |
| LBLj OA PRJ | LBL | 30.01 |
| LBLj CL PRJ | LBL | 20.02 |
| LBLj SH PRJ | LBL | 52.44 |
| LBLj TS PRJ | LBL | 52.44 |
| LBLj ST PRJ | LBL | 15.11 |
| LBLj PM PRJ | LBL | 0.11 |
| LBLj S PRJ | LBL |  |
| LBLj TR PRJ | LBL | 0.11 |
| LBLj LW PRJ | LBL | 0.11 |
| LBLj RD PRJ | LBL | 0.05 |
| LBLj HI PRJ | LBL | 0.05 |
| LBLs SP PRJ | LBL | 100 |
| LBLs EE PRJ | LBL | 105.06 |
| LBLs ME PRJ | LBL | 105.06 |
| LBLs DS PRJ | LBL | 49.96 |
| LBLs ET PRJ | LBL | 49.96 |
| LBLs MT PRJ | LBL | 49.96 |
| LBLs AS PRJ | LBL | 47.56 |
| LBLs OA PRJ | LBL | 47.56 |
| LBLs CL PRJ | LBL | 22.06 |
| LBLs SH PRJ | LBL | 52.44 |
| LBLs TS PRJ | LBL | 49.91 |
| LBLs ST PRJ | LBL | 15.11 |
| LBLs PM PRJ | LBL | 0.11 |
| LBLs S PRJ | LBL |  |
| LBLs TR PRJ | LBL | 0.11 |
| LBLs LW PRJ | LBL | 0.11 |
| LBLs RD PRJ | LBL | 0.05 |
| LBLs HI PRJ | LBL | 0.05 |
| SUNYA SP PRJ | SUNYA |  |
| SUNYA EE PRJ | SUNYA |  |
| SUNYA ME PRJ | SUNYA |  |
| SUNYA DS PRJ | SUNYA | 27.93 |
| SUNYA ET PRJ | SUNYA | 27.93 |
| SUNYA MT PRJ | SUNYA | 27.93 |
| SUNYA AS PRJ | SUNYA | 27.93 |
| SUNYA OA PRJ | SUNYA | 27.93 |
| SUNYA CL PRJ | SUNYA |  |
| SUNYA SH PRJ | SUNYA | 27.93 |
| SUNYA TS PRJ | SUNYA | 27.93 |
| SUNYA ST PRJ | SUNYA | 14.7 |
| SUNYA PM PRJ | SUNYA |  |
| SUNYA S PRJ | SUNYA |  |
| SUNYA TR PRJ | SUNYA |  |
| SUNYA LW PRJ | SUNYA |  |
| SUNYA RD PRJ | SUNYA | 0.47 |
| SUNYA HI PRJ | SUNYA |  |
| UNM SP PRJ | UNM | 40.32 |
| UNM EE PRJ | UNM | 43.95 |
| UNM ME PRJ | UNM | 40.32 |
| UNM DS PRJ | UNM | 22.68 |
| UNM ET PRJ | UNM | 22.68 |
| UNM MT PRJ | UNM | 22.68 |
| UNM AS PRJ | UNM | 22.68 |
| UNM OA PRJ | UNM | 22.68 |
| UNM CL PRJ | UNM | 18.9 |
| UNM SH PRJ | UNM | 49.14 |
| UNM TS PRJ | UNM | 49.14 |
| UNM ST PRJ | UNM | 10.99 |
| UNM PM PRJ | UNM |  |
| UNM S PRJ | UNM |  |
| UNM TR PRJ | UNM |  |
| UNM LW PRJ | UNM |  |
| UNM RD PRJ | UNM |  |
| UNM HI PRJ | UNM |  |
| UOK SP PRJ | UOK | 45.57 |
| UOK EE PRJ | UOK | 45.57 |
| UOK ME PRJ | UOK | 45.57 |
| UOK DS PRJ | UOK | 31.6 |
| UOK ET PRJ | UOK | 33.7 |
| UOK MT PRJ | UOK | 31.6 |
| UOK AS PRJ | UOK | 31.6 |
| UOK OA PRJ | UOK | 31.6 |
| UOK CL PRJ | UOK | 13.23 |
| UOK SH PRJ | UOK | 13.23 |
| UOK TS PRJ | UOK | 13.23 |
| UOK ST PRJ | UOK | 10.99 |
| UOK PM PRJ | UOK |  |
| UOK S PRJ | UOK |  |
| UOK TR PRJ | UOK | 0.15 |
| UOK LW PRJ | UOK |  |
| UOK RD PRJ | UOK |  |
| UOK HI PRJ | UOK |  |
| OSU PM PRJ | OSU |  |
| OSU LW PRJ | OSU |  |
| OSU ST PRJ | OSU | 11.61 |
| OSU ET PRJ | OSU | 36.5 |
| OSU EE PRJ | OSU | 66.36 |
| OSU CL PRJ | OSU | 21.56 |
| OSU MT PRJ | OSU | 36.5 |
| OSU HI PRJ | OSU |  |

## Schedule

| ID | WBS | Task | Type | Duration | Start | Finish | Predecessors | Total slack | Free slack | Constraint | Resources | Work | Cost |
| --- | --- | --- | --- | --- | --- | --- | --- | --- | --- | --- | --- | --- | --- |
| 1 | 1.1.1 | **US ATLAS Pixel Project** |  | 1305d | 2000-10-02 | 2005-09-30 |  | 0d |  |  |  | 67099h | 6,381,669.33 |
| 2 | 1.1.1.1 | **Mechanics** |  | 1185d | 2000-10-02 | 2005-04-15 |  | 120d |  |  |  | 22266h | 3,067,108.16 |
| 3 | 1.1.1.1.1 | **Design** |  | 1185d | 2000-10-02 | 2005-04-15 |  | 120d |  |  |  | 12320h | 1,375,240.2 |
| 4 | 1.1.1.1 | Mechanics Engineering FY01 $s |  | 260d | 2000-10-02 | 2001-09-28 |  | 1045d |  | start no earlier than 2000-10-02 | UNM EE PRJ [42.3%]; UNM TR PRJ; LBLj DS PRJ [63.5%]; LBLj ME PRJ [84.6%]; LBLj TR PRJ; LBLj PM PRJ; LBLs PM PRJ; LBLs DS PRJ [10.6%] | 4180h | 571,176.6 |
| 5 | 1.1.1.2 | Mechanics Engineering FY02 $s |  | 261d | 2001-10-01 | 2002-09-30 |  | 784d |  | start no earlier than 2001-10-01 | LBLj DS PRJ [42.1%]; LBLj ME PRJ [84.3%]; LBLj EE PRJ [42.1%]; LBLj TR PRJ; LBLs DS PRJ [10.5%]; LBLs PM PRJ; LBLs TR PRJ | 3740h | 447,304.8 |
| 6 | 1.1.1.3 | Mechanics Engineering FY03 $s |  | 261d | 2002-10-01 | 2003-09-30 |  | 523d |  | start no earlier than 2002-10-01 | LBLj DS PRJ [42.1%]; LBLj ME PRJ [84.3%]; LBLj EE PRJ [21.1%]; LBLj TR PRJ; LBLs DS PRJ [21.1%]; LBLs PM PRJ; LBLs TR PRJ | 3520h | 261,872 |
| 7 | 1.1.1.4 | Mechanics Engineering FY04 $s |  | 262d | 2003-10-01 | 2004-09-30 |  | 261d |  | start no earlier than 2003-10-01 | LBLj DS PRJ [21%]; LBLj ME PRJ [21%]; LBLj TR PRJ; LBLs TR PRJ | 880h | 82,886.8 |
| 8 | 1.1.1.5 | Mechanics Engineering FY05 $s |  | 141d | 2004-10-01 | 2005-04-15 |  | 120d |  | start no earlier than 2004-10-01 | LBLs TR PRJ |  | 12,000 |
| 9 | 1.1.1.6 | Release bids for global support | milestone | 0d | 2002-02-26 | 2002-02-26 | 11 | 914d | 0d |  |  |  |  |
| 10 | 1.1.1.7 | Bid evaluation complete for support | milestone | 0d | 2002-03-25 | 2002-03-25 | 9FS+20d | 914d | 0d |  |  |  |  |
| 11 | 1.1.1.8 | Global Support PRR | milestone | 0d | 2002-02-26 | 2002-02-26 |  | 529d | 0d | start no earlier than 2002-02-26 |  |  |  |
| 12 | 1.1.1.9 | ATLAS PM approval of global support procurement | milestone | 0d | 2002-04-01 | 2002-04-01 | 10FS+5d | 914d |  |  |  |  |  |
| 13 | 1.1.1.10 | Support tube FDR | milestone | 0d | 2002-06-17 | 2002-06-17 |  | 860d | 0d | start no earlier than 2002-06-17 |  |  |  |
| 14 | 1.1.1.11 | Support tube PRR | milestone | 0d | 2002-12-16 | 2002-12-16 |  | 465d | 0d | start no earlier than 2002-12-16 |  |  |  |
| 15 | 1.1.1.12 | Cables/services FDR | milestone | 0d | 2002-06-17 | 2002-06-17 | 13 | 860d |  | start no earlier than 2001-09-03 |  |  |  |
| 16 | 1.1.1.13 | Release bids for initial cables | milestone | 0d | 2002-12-06 | 2002-12-06 | 17FF-40d | 735d |  |  |  |  |  |
| 17 | 1.1.1.14 | Bid evaluation complete for outer cables | milestone | 0d | 2003-01-31 | 2003-01-31 | 18FF-10d | 695d | 0d |  |  |  |  |
| 18 | 1.1.1.15 | Cables/services PRR | milestone | 0d | 2003-02-17 | 2003-02-17 |  | 125d | 0d | start no earlier than 2003-02-17 |  |  |  |
| 19 | 1.1.1.16 | ATLAS PM approval of outer cables procurement | milestone | 0d | 2003-02-21 | 2003-02-21 | 18FS+5d | 680d |  |  |  |  |  |
| 20 | 1.1.1.17 | Assembly/Installation CDR | milestone | 0d | 2002-02-26 | 2002-02-26 | 11 | 939d |  |  |  |  |  |
| 21 | 1.1.1.18 | Assembly/Installation FDR | milestone | 0d | 2002-12-16 | 2002-12-16 |  | 730d |  | start no earlier than 2002-12-16 |  |  |  |
| 22 | 1.1.1.19 | Assembly/Installation PRR | milestone | 0d | 2003-06-16 | 2003-06-16 |  | 335d | 0d | start no earlier than 2003-06-16 |  |  |  |
| 23 | 1.1.1.1.2 | **Development/Prototypes** |  | 707d | 2000-10-02 | 2003-06-17 |  | 598d |  |  |  | 1713h | 256,964.76 |
| 24 | 1.1.2.1 | Development/Prototypes FY01 $s |  | 260d | 2000-10-02 | 2001-09-28 |  | 1045d |  | start no earlier than 2000-10-02 | LBLs MT PRJ [10.6%]; LBLs ET PRJ [4.8%]; LBLs SH PRJ [33.9%]; LBLs PM PRJ; LBLj SH PRJ [10.2%]; LBLj PM PRJ | 1237h | 152,236.68 |
| 25 | 1.1.2.2 | Development/Prototypes FY02 $s |  | 261d | 2001-10-01 | 2002-09-30 |  | 784d |  | start no earlier than 2001-10-01 | LBLs ET PRJ [3.9%]; LBLs SH PRJ [14.1%]; LBLs PM PRJ; LBLj SH PRJ [4.8%]; LBLj PM PRJ | 476h | 104,728.08 |
| 26 | 1.1.2.3 | Development/Prototypes FY03 $s |  | 186d | 2002-10-01 | 2003-06-17 |  | 598d |  | start no earlier than 2002-10-01 |  |  |  |
| 27 | 1.1.2.4 | Support tube development/prototypes |  | 240d | 2001-07-16 | 2002-06-17 | 13FF | 860d | 0d |  |  |  |  |
| 28 | 1.1.2.5 | Support tube development complete | milestone | 0d | 2002-06-17 | 2002-06-17 | 27 | 860d |  |  |  |  |  |
| 29 | 1.1.2.6 | Outer services development/prototypes |  | 400d | 2001-08-06 | 2003-02-17 | 18FF | 685d | 0d | start no earlier than 2000-10-02 |  |  |  |
| 30 | 1.1.2.7 | Compl. Outer services development/prototypes | milestone | 0d | 2003-02-17 | 2003-02-17 | 29 | 685d |  |  |  |  |  |

| ID | WBS | Task | Type | Duration | Start | Finish | Predecessors | Total slack | Free slack | Constraint | Resources | Work | Cost |
| --- | --- | --- | --- | --- | --- | --- | --- | --- | --- | --- | --- | --- | --- |
| 31 | 1.1.1.1.3 | **Production** |  | 983d | 2001-07-11 | 2005-04-15 |  | 120d |  |  |  | 8233h | 1,434,903.2 |
| 32 | 1.1.3.1 | Production FY01 $s |  | 58d | 2001-07-11 | 2001-09-28 |  | 1045d |  | start no earlier than 2001-07-11 | LBLs HI PRJ; LBLs PM PRJ; LBLj MT PRJ [189.7%]; LBLj SH PRJ [108%]; LBLj PM PRJ | 1381h | 199,276.04 |
| 33 | 1.1.3.2 | Production FY02 $s |  | 261d | 2001-10-01 | 2002-09-30 |  | 784d |  | start no earlier than 2001-10-01 | LBLs ET PRJ; LBLs MT PRJ; LBLs SH PRJ; LBLs HI PRJ; LBLs PM PRJ; LBLj MT PRJ [42.1%] | 1377h | 365,328.12 |
| 34 | 1.1.3.3 | Production FY03 $s |  | 261d | 2002-10-01 | 2003-09-30 |  | 523d |  | start no earlier than 2002-10-01 | LBLs ET PRJ [62.1%]; LBLs MT PRJ [27.9%]; LBLs SH PRJ [128.2%]; LBLs HI PRJ; LBLs PM PRJ; LBLs S PRJ; LBLj ET PRJ [17.3%]; LBLj SH PRJ [11.1%]; LBLj PM PRJ | 5149h | 769,799.6 |
| 35 | 1.1.3.4 | Production FY04 $s |  | 262d | 2003-10-01 | 2004-09-30 |  | 261d |  | start no earlier than 2003-10-01 | LBLs SH PRJ [15.6%]; LBLs PM PRJ; LBLs S PRJ | 326h | 93,821.44 |
| 36 | 1.1.3.5 | Production FY05 $s |  | 141d | 2004-10-01 | 2005-04-15 |  | 120d |  | start no earlier than 2004-10-01 | LBLs PM PRJ |  | 6,678 |
| 37 | 1.1.3.6 | Disk Sector Fab/Test |  | 260d | 2001-10-01 | 2002-09-27 |  | 600d | 458d | start no earlier than 2001-10-01 |  |  |  |
| 38 | 1.1.3.7 | Disk Support Ring Fab/Test |  | 125d | 2002-04-09 | 2002-09-30 | 11FS+30d | 784d |  |  |  |  |  |
| 39 | 1.1.3.8 | Support Frame Fab/Test |  | 260d | 2002-04-09 | 2003-04-07 | 11FS+30d | 529d | 0d | start no earlier than 2000-11-16 |  |  |  |
| 40 | 1.1.3.9 | Support tubes Fab/Test |  | 265d | 2002-12-16 | 2003-12-19 | 14 | 465d |  | start no earlier than 2001-10-15 |  |  |  |
| 41 | 1.1.3.10 | Outer Services Fab/Test |  | 530d | 2003-03-31 | 2005-04-08 | 18FS+30d | 125d | 0d |  |  |  |  |
| 42 | 1.1.3.11 | Services Compl. For Initial Cryo/Hall Installation | milestone | 0d | 2004-01-16 | 2004-01-16 | 41SS+210d | 445d |  |  |  |  |  |
| 43 | 1.1.3.12 | Services Complete for Initial Assembly | milestone | 0d | 2004-01-08 | 2004-01-08 | 48SS | 452d |  |  |  |  |  |
| 44 | 1.1.3.13 | All Outer Services Complete | milestone | 0d | 2005-04-08 | 2005-04-08 | 41 | 125d |  |  |  |  |  |
| 45 | 1.1.3.14 | Trial Outer Structure Assembly |  | 120d | 2003-04-08 | 2003-09-22 | 39 | 529d | 0d | start no earlier than 2001-08-03 |  |  |  |
| 46 | 1.1.3.15 | Outer Structure Complete/Ready for Modules | milestone | 0d | 2003-09-22 | 2003-09-22 | 45 | 529d |  |  |  |  |  |
| 47 | 1.1.3.16 | Outer Structure Needed for Modules | milestone | 0d | 2004-01-07 | 2004-01-07 | 237SS+10d | 452d |  |  |  |  |  |
| 48 | 1.1.3.17 | Disk Assembly/Test |  | 180d | 2004-01-08 | 2004-09-15 | 237SS+10d | 142d | 0d |  |  |  |  |
| 49 | Sil L2/9; Sil L3/1 | Disk System at CERN | milestone | 0d | 2004-10-13 | 2004-10-13 | 48FS+20d | 142d | 0d | start no earlier than 2003-04-03 |  |  |  |
| 50 | 1.1.3.19 | Fab services supports |  | 200d | 2003-07-14 | 2004-04-16 | 22FS+20d | 335d | 0d |  |  |  |  |
| 51 | 1.1.3.20 | Trial assembly services supports |  | 45d | 2004-04-19 | 2004-06-18 | 50 | 335d |  |  |  |  |  |
| 52 | 1.1.3.21 | Outer System Assembly/Test at CERN |  | 110d | 2004-10-14 | 2005-03-16 | 49 | 142d | 0d |  |  |  |  |
| 53 | 1.1.3.22 | Outer System Ready for Installation | milestone | 0d | 2005-03-16 | 2005-03-16 | 52 | 142d |  |  |  |  |  |
| 54 | 1.1.3.23 | ATLAS need date for installation for pilot run | milestone | 0d | 2005-04-15 | 2005-04-15 |  | 121d |  | start no earlier than 2005-04-15 |  |  |  |

Notes:
- 45: Trial assembly of frame sections and disk rings. B-layer structures not ready.
- 48: Disk is assembled as sectors are completed and tested. Disks inserted in frame as completed.
- 54: This is estimate. Final installation schedule not firm.

| ID | WBS | Task | Type | Duration | Start | Finish | Predecessors | Total slack | Free slack | Constraint | Resources | Work | Cost |
| --- | --- | --- | --- | --- | --- | --- | --- | --- | --- | --- | --- | --- | --- |
| 56 | 1.1.1.2 | **Sensors** |  | 988d | 2000-10-02 | 2004-07-14 |  | 317d |  |  |  | 3798h | 132,610.5 |
| 57 | 1.1.1.2.1 | **Design** |  | 410d | 2000-10-30 | 2002-05-24 |  | 875d |  |  |  | 1598h | 70,232.1 |
| 58 | 1.2.1.1 | Sensors Design FY01 $s |  | 240d | 2000-10-30 | 2001-09-28 |  | 1045d |  | start no earlier than 2000-10-30 | UNM EE PRJ [41.6%] | 799h | 35,116.05 |
| 59 | 1.2.1.2 | Sensors Design FY02 $s |  | 80d | 2001-10-01 | 2002-01-18 |  | 965d |  | start no earlier than 2001-10-01 | UNM EE PRJ [124.8%] | 799h | 35,116.05 |
| 60 | 1.2.1.3 | Test Design |  | 390d | 2000-11-27 | 2002-05-24 | 69FF | 875d |  | start no earlier than 2000-10-02 |  |  |  |
| 61 | 1.2.1.4 | ATLAS PM approval of production procurement | milestone | 0d | 2001-11-26 | 2001-11-26 | 68SS-30d | 1005d | 0d |  |  |  |  |
| 62 | 1.2.1.5 | Release initial MC for sensors/testing | milestone | 0d | 2001-11-26 | 2001-11-26 | 61 | 1005d |  |  |  |  |  |
| 63 | 1.1.1.2.3 | **Production** |  | 988d | 2000-10-02 | 2004-07-14 |  | 317d |  |  |  | 2200h | 62,378.4 |
| 64 | 1.2.2.1 | Sensors Production FY01 $s |  | 260d | 2000-10-02 | 2001-09-28 |  | 1045d |  | start no earlier than 2000-10-02 | SUNYA PM PRJ; UNM EE PRJ; UNM PM PRJ; UNM ST PRJ [84.6%] | 2200h | 62,378.4 |
| 65 | 1.2.2.2 | Sensors Production FY02 $s |  | 261d | 2001-10-01 | 2002-09-30 |  | 784d |  | start no earlier than 2001-10-01 |  |  |  |
| 66 | 1.2.2.3 | Sensors Production FY03 $s |  | 261d | 2002-10-01 | 2003-09-30 |  | 523d |  | start no earlier than 2002-10-01 |  |  |  |
| 67 | 1.2.2.4 | Sensors Production FY04 $s |  | 3d | 2003-10-01 | 2003-10-03 |  | 520d |  | start no earlier than 2003-10-01 |  |  |  |
| 68 | 1.2.2.5 | Outer Sensors Production |  | 250d | 2002-01-07 | 2002-12-20 |  | 430d | 0d | start no earlier than 2002-01-07 |  |  |  |
| 69 | 1.2.2.6 | First Outer production wafers delivered | milestone | 0d | 2002-05-24 | 2002-05-24 | 68SS+100d | 430d | 0d |  |  |  |  |
| 70 | 1.2.2.7 | Outer Sensors Testing |  | 220d | 2002-05-27 | 2003-03-28 | 69 | 430d | 0d |  |  |  |  |
| 71 | 1.2.2.8 | Outer Sensors Testing Complete | milestone | 0d | 2003-03-28 | 2003-03-28 | 70 | 430d | 0d |  |  |  |  |
| 72 | 1.2.2.9 | Outer Sensors Need to Begin Module Production | milestone | 0d | 2003-07-31 | 2003-07-31 | 142SS | 567d |  |  |  |  |  |
| 73 | 1.2.2.10 | B-Layer Production |  | 125d | 2003-03-31 | 2003-09-19 | 71 | 430d | 0d | start no earlier than 2002-06-03 |  |  |  |
| 74 | 1.2.2.11 | First B-layer wafers delivered | milestone | 0d | 2003-08-15 | 2003-08-15 | 73SS+100d | 430d | 0d |  |  |  |  |
| 75 | 1.2.2.12 | B-layer sensor testing |  | 125d | 2003-08-18 | 2004-02-06 | 74 | 430d |  |  |  |  |  |
| 76 | 1.2.2.13 | B-layer sensors needed to begin modules | milestone | 0d | 2004-07-14 | 2004-07-14 | 239 | 317d |  |  |  |  |  |
| 78 | 1.1.1.3 | **Electronics** |  | 988d | 2000-10-02 | 2004-07-14 |  | 317d |  |  |  | 12532h | 1,616,495.96 |
| 79 | 1.1.1.3.1 | **Design** |  | 823d | 2000-10-02 | 2003-11-26 |  | 482d |  |  |  | 9592h | 988,642.56 |
| 80 | 1.3.1.1 | Elec.'s Design FY01 $s |  | 260d | 2000-10-02 | 2001-09-28 |  | 1045d |  | start no earlier than 2000-10-02 | LBLs EE PRJ [114.2%]; LBLs TR PRJ; LBLj EE PRJ [50.8%]; LBLj TR PRJ; OSU EE PRJ [21.1%] | 3872h | 381,344.16 |
| 81 | 1.3.1.2 | Elec.'s Design FY02 $s |  | 261d | 2001-10-01 | 2002-09-30 |  | 784d |  | start no earlier than 2001-10-01 | LBLs EE PRJ [147.5%]; LBLs TR PRJ; LBLj EE PRJ [42.1%]; LBLj TR PRJ; OSU EE PRJ [21.1%] | 4400h | 445,819.2 |
| 82 | 1.3.1.3 | Elec.'s Design FY03 $s |  | 261d | 2002-10-01 | 2003-09-30 |  | 523d |  | start no earlier than 2002-10-01 | LBLs EE PRJ [63.2%]; LBLs TR PRJ; LBLj TR PRJ | 1320h | 161,479.2 |
| 83 | 1.3.1.4 | Elec.'s Design FY04 $s |  | 41d | 2003-10-01 | 2003-11-26 |  | 482d |  | start no earlier than 2003-10-01 |  |  |  |
| 84 | 1.3.1.5 | Outer layers design |  | 633d | 2000-10-02 | 2003-03-05 | 96FF | 672d |  | start no earlier than 2000-10-02 |  |  |  |
| 85 | 1.3.1.6 | B-layer design |  | 390d | 2002-05-23 | 2003-11-19 | 103FF | 487d |  | start no earlier than 2000-10-02 |  |  |  |
| 86 | 1.3.1.7 | Test design |  | 418d | 2000-10-02 | 2002-05-08 | 93FF | 887d |  | start no earlier than 2000-10-02 |  |  |  |
| 87 | 1.3.1.8 | DMILL Review | milestone | 0d | 2000-12-15 | 2000-12-15 |  | 1251d |  | start no earlier than 2000-12-15 |  |  |  |
| 88 | 1.3.1.9 | DMILL decision(FE-D3 or not) | milestone | 0d | 2001-02-15 | 2001-02-15 |  | 852d | 0d | start no earlier than 2001-02-15 |  |  |  |
| 89 | 1.3.1.10 | FE-I1 spec complete | milestone | 0d | 2001-05-16 | 2001-05-16 | 90FF-20d | 1142d |  |  |  |  |  |
| 90 | 1.3.1.11 | FE-I1 FDR | milestone | 0d | 2001-06-13 | 2001-06-13 | 123FF-30d | 1122d | 0d |  |  |  |  |
| 91 | 1.3.1.12 | Management contingency decision DMILL | milestone | 0d | 2002-01-09 | 2002-01-09 | 122 | 972d |  |  |  |  |  |
| 92 | 1.3.1.13 | FE-I2 spec complete | milestone | 0d | 2002-04-10 | 2002-04-10 | 93FF-20d | 907d |  |  |  |  |  |
| 93 | 1.3.1.14 | FE-I2 FDR | milestone | 0d | 2002-05-08 | 2002-05-08 | 127 | 142d | 0d | start no earlier than 2001-07-25 |  |  |  |
| 94 | 1.3.1.15 | Compl. Spec forIBM production order release | milestone | 0d | 2002-11-21 | 2002-11-21 | 95SS-15d | 747d |  |  |  |  |  |
| 95 | 1.3.1.16 | IBM Production release order effort |  | 60d | 2002-12-12 | 2003-03-05 | 96FF | 672d | 0d |  |  |  |  |
| 96 | 1.3.1.17 | IBM FE PRR | milestone | 0d | 2003-03-05 | 2003-03-05 | 133 | 142d | 0d | start no earlier than 2002-10-15 |  |  |  |
| 97 | 1.3.1.18 | ATLAS PM approval of IBM procurement | milestone | 0d | 2003-03-12 | 2003-03-12 | 96FS+5d | 142d | 0d | start no earlier than 2002-04-22 |  |  |  |
| 98 | 1.3.1.19 | Release initial MC for IBM FE | milestone | 0d | 2003-03-12 | 2003-03-12 | 97 | 142d | 0d |  |  |  |  |
| 99 | 1.3.1.20 | Release IBM production | milestone | 0d | 2003-03-12 | 2003-03-12 | 98 | 142d | 0d |  |  |  |  |
| 100 | 1.3.1.21 | B-Layer FDR | milestone | 0d | 2003-03-05 | 2003-03-05 | 96 | 672d |  | start no earlier than 2002-11-15 |  |  |  |
| 101 | 1.3.1.22 | Compl. Spec for B-Layer prod order release | milestone | 0d | 2003-06-05 | 2003-06-05 | 102SS-30d | 607d |  |  |  |  |  |
| 102 | 1.3.1.23 | Production release order effort |  | 90d | 2003-07-17 | 2003-11-19 | 103FF | 487d | 0d |  |  |  |  |
| 103 | 1.3.1.24 | B-Layer PRR | milestone | 0d | 2003-11-19 | 2003-11-19 | 142SS+80d | 252d | 0d | start no earlier than 2002-06-04 |  |  |  |
| 104 | 1.3.1.25 | ATLAS PM Approval of B-Layer Proc. | milestone | 0d | 2003-11-26 | 2003-11-26 | 103FS+5d | 482d | 0d |  |  |  |  |
| 105 | 1.3.1.26 | Release initial MC for B-layer production | milestone | 0d | 2003-11-26 | 2003-11-26 | 104 | 482d | 0d |  |  |  |  |
| 106 | 1.3.1.27 | Release B-Layer Production | milestone | 0d | 2003-11-26 | 2003-11-26 | 105 | 482d |  |  |  |  |  |
| 107 | 1.3.1.28 | Optical IC design |  | 633d | 2000-10-02 | 2003-03-05 | 96FF | 672d |  | start no earlier than 2000-10-02 |  |  |  |
| 108 | 1.3.1.29 | Optical IC FDR | milestone | 0d | 2002-05-08 | 2002-05-08 | 93 | 887d |  |  |  |  |  |
| 109 | 1.3.1.30 | Optical IC PRR | milestone | 0d | 2003-03-05 | 2003-03-05 | 96 | 462d | 0d |  |  |  |  |
| 110 | 1.3.1.31 | Release initial MC for optical IC | milestone | 0d | 2003-03-12 | 2003-03-12 | 109FS+5d | 667d |  |  |  |  |  |

| ID | WBS | Task | Type | Duration | Start | Finish | Predecessors | Total slack | Free slack | Constraint | Resources | Cost |
| --- | --- | --- | --- | --- | --- | --- | --- | --- | --- | --- | --- | --- |
| 111 | 1.1.1.3.2 | **Development/Prototypes** |  | 724d | 2001-01-08 | 2003-10-16 |  | 285d |  |  |  | 367,136 |
| 112 | 1.3.2.1 | Elec.'s Develop/Protos FY01 $s |  | 190d | 2001-01-08 | 2001-09-28 |  | 1045d |  | start no earlier than 2001-01-08 | LBLj PM PRJ; LBLs PM PRJ; OSU LW PRJ; SUNYA PM PRJ | 234,053 |
| 113 | 1.3.2.2 | Elec.'s Develop/Protos FY02 $s |  | 261d | 2001-10-01 | 2002-09-30 |  | 784d |  | start no earlier than 2001-10-01 | LBLs HI PRJ; OSU HI PRJ | 133,083 |
| 114 | 1.3.2.3 | Elec.'s Develop/Protos FY03 $s |  | 261d | 2002-10-01 | 2003-09-30 |  | 523d |  | start no earlier than 2002-10-01 |  |  |
| 115 | 1.3.2.4 | Elec.'s Develop/Protos FY04 $s |  | 12d | 2003-10-01 | 2003-10-16 |  | 511d |  | start no earlier than 2003-10-01 |  |  |
| 116 | 1.3.2.5 | Submit TSMC digital test chip | milestone | 0d | 2001-01-08 | 2001-01-08 |  | 1185d | 0d | start no earlier than 2001-01-08 |  |  |
| 117 | 1.3.2.6 | Digital test chip delivered | milestone | 0d | 2001-03-16 | 2001-03-16 | 116FS+50d | 1185d |  |  |  |  |
| 118 | 1.3.2.7 | Submit TSMC analog test chip | milestone | 0d | 2001-03-05 | 2001-03-05 |  | 1145d | 0d | start no earlier than 2001-03-05 |  |  |
| 119 | 1.3.2.8 | Analog test chip delivered | milestone | 0d | 2001-05-11 | 2001-05-11 | 118FS+50d | 1145d |  |  |  |  |
| 120 | 1.3.2.9 | FE-D3 submitted | milestone | 0d | 2001-05-02 | 2001-05-02 | 88FS+55d | 852d | 0d |  |  |  |
| 121 | 1.3.2.10 | FE-D3 wafers arrive | milestone | 0d | 2001-08-22 | 2001-08-22 | 120FS+80d | 852d | 0d |  |  |  |
| 122 | 1.3.2.11 | FE-D3 wafer tests complete | milestone | 0d | 2002-01-09 | 2002-01-09 | 121FS+100d | 852d | 0d |  |  |  |
| 123 | Sil L2/6 | 1st IBM prototype submitted(FE-I1) | milestone | 0d | 2001-07-26 | 2001-07-26 |  | 142d | 0d | start no earlier than 2001-07-26 |  |  |
| 124 | 1.3.2.13 | 1st IBM prototype delivered | milestone | 0d | 2001-10-24 | 2001-10-24 | 123FS+65d | 142d | 0d |  |  |  |
| 125 | 1.3.2.14 | Complete initial wafer probe FE-I1 | milestone | 0d | 2001-11-07 | 2001-11-07 | 124FS+10d | 142d | 0d |  |  |  |
| 126 | 1.3.2.15 | First bump bonded FE-I1 assemblies arrive | milestone | 0d | 2002-01-09 | 2002-01-09 | 125FS+45d | 972d |  |  |  |  |
| 127 | 1.3.2.16 | Complete initial lab/ irradiation tests FE-I1 | milestone | 0d | 2002-05-08 | 2002-05-08 | 125FS+130d | 142d | 0d |  |  |  |
| 128 | 1.3.2.17 | Beam/system tests of FE-I1 assemblies |  | 160d | 2002-03-01 | 2002-10-10 |  | 776d |  | start no earlier than 2002-03-01 |  |  |
| 129 | 1.3.2.18 | 2nd IBM prototype submitted(FE-I2) | milestone | 0d | 2002-06-19 | 2002-06-19 | 93FS+30d | 142d | 0d | start no earlier than 2001-10-14 |  |  |
| 130 | 1.3.2.19 | 2nd IBM prototype wafers delivered | milestone | 0d | 2002-09-18 | 2002-09-18 | 129FS+65d | 142d | 0d |  |  |  |
| 131 | 1.3.2.20 | Complete initial wafer probe FE-I2 | milestone | 0d | 2002-10-30 | 2002-10-30 | 130FS+30d | 762d |  |  |  |  |
| 132 | 1.3.2.21 | First bump bonded FE-I2assemblies arrive | milestone | 0d | 2002-11-27 | 2002-11-27 | 130SS+50d | 742d |  |  |  |  |
| 133 | 1.3.2.22 | Complete initial lab/system/ irradiation tests FE-I2 | milestone | 0d | 2003-03-05 | 2003-03-05 | 130FS+120d | 142d | 0d |  |  |  |
| 134 | 1.3.2.23 | Beam/system tests of FE-I2 assemblies |  | 200d | 2003-01-10 | 2003-10-16 |  | 511d |  | start no earlier than 2003-01-10 |  |  |

| ID | WBS | Task | Type | Duration | Start | Finish | Predecessors | Total slack | Free slack | Constraint | Resources | Work | Cost |
| --- | --- | --- | --- | --- | --- | --- | --- | --- | --- | --- | --- | --- | --- |
| 135 | 1.1.1.3.3 | **Production** |  | 598d | 2002-04-01 | 2004-07-14 |  | 317d |  |  |  | 2940h | 260,717.4 |
| 136 | 1.3.3.1 | Elec.'s Production FY02 $s |  | 131d | 2002-04-01 | 2002-09-30 |  | 784d |  | start no earlier than 2002-04-01 | LBLs PM PRJ; OSU LW PRJ |  | 41,821 |
| 137 | 1.3.3.2 | Elec.'s Production FY03 $s |  | 261d | 2002-10-01 | 2003-09-30 |  | 523d |  | start no earlier than 2002-10-01 | LBLs CL PRJ [84.3%]; LBLs HI PRJ; LBLs PM PRJ; OSU HI PRJ; OSU LW PRJ; OSU ST PRJ [14.4%] | 2060h | 192,805.6 |
| 138 | 1.3.3.3 | Elec.'s Production FY04 $s |  | 206d | 2003-10-01 | 2004-07-14 |  | 317d |  | start no earlier than 2003-10-01 | LBLs CL PRJ [53.4%]; LBLs PM PRJ | 880h | 26,090.8 |
| 139 | Sil L2/7 | Start IBM Production | milestone | 0d | 2003-03-13 | 2003-03-13 |  | 667d |  | start no earlier than 2003-03-13 |  |  |  |
| 140 | 1.3.3.5 | Outer FE IBM Production |  | 250d | 2003-03-13 | 2004-02-25 | 99 | 142d | 0d | start no earlier than 2001-09-03 |  |  |  |
| 141 | 1.3.3.6 | 1st outer IBM wafers arrive | milestone | 0d | 2003-07-30 | 2003-07-30 | 140SS+100d | 142d | 0d |  |  |  |  |
| 142 | 1.3.3.7 | Test outer FE IBM wafers |  | 250d | 2003-07-31 | 2004-07-14 | 141 | 142d | 0d |  |  |  |  |
| 143 | 1.3.3.8 | Outer IBM FE Testing complete | milestone | 0d | 2004-07-14 | 2004-07-14 | 142 | 317d |  |  |  |  |  |
| 144 | 1.3.3.9 | B-Layer FE Production |  | 120d | 2003-11-20 | 2004-05-05 | 103 | 252d | 0d |  |  |  |  |
| 145 | 1.3.3.10 | 1st B-Layer wafers arrive | milestone | 0d | 2004-04-07 | 2004-04-07 | 144SS+100d | 252d | 0d |  |  |  |  |
| 146 | 1.3.3.11 | Test B-layer wafers |  | 50d | 2004-04-08 | 2004-06-16 | 145 | 252d | 0d |  |  |  |  |
| 147 | 1.3.3.12 | B-Layer testing complete | milestone | 0d | 2004-06-16 | 2004-06-16 | 146 | 337d |  |  |  |  |  |
| 148 | 1.3.3.13 | Optical IC production |  | 100d | 2003-05-01 | 2003-09-17 | 109FS+40d | 487d | 0d |  |  |  |  |
| 149 | 1.3.3.14 | 1st Production Optical ICs | milestone | 0d | 2003-08-27 | 2003-08-27 | 148SS+85d | 487d | 0d |  |  |  |  |
| 150 | 1.3.3.15 | Test optical Ics |  | 60d | 2003-08-28 | 2003-11-19 | 149 | 487d | 0d |  |  |  |  |
| 151 | 1.3.3.16 | Optical IC testing complete | milestone | 0d | 2003-11-19 | 2003-11-19 | 150 | 487d |  |  |  |  |  |
| 153 | 1.1.1.4 | **Flex Hybrids/Optical Hybrids** |  | 989d | 2000-10-02 | 2004-07-15 |  | 316d |  |  |  | 7900h | 524,984.5 |
| 154 | 1.1.1.4.1 | **Design** |  | 643d | 2000-10-02 | 2003-03-19 |  | 610d |  |  |  | 3080h | 77,366 |
| 155 | 1.4.1.1 | Hybrids Design FY01 $s |  | 260d | 2000-10-02 | 2001-09-28 |  | 1045d |  | start no earlier than 2000-10-02 | UOK ST PRJ [42.3%]; UOK TR PRJ | 880h | 18,461.2 |
| 156 | 1.4.1.2 | Hybrids Design FY02 $s |  | 261d | 2001-10-01 | 2002-09-30 |  | 784d |  | start no earlier than 2001-10-01 | LBLs DS PRJ [21.1%]; UOK ST PRJ [84.3%]; UOK TR PRJ | 2200h | 50,114.8 |
| 157 | 1.4.1.3 | Hybrids Design FY03 $s |  | 122d | 2002-10-01 | 2003-03-19 |  | 662d |  | start no earlier than 2002-10-01 | UOK TR PRJ |  | 8,790 |
| 158 | 1.4.1.4 | Flex 2.x Test Analysis |  | 200d | 2000-10-02 | 2001-07-06 | 159FF+140d | 1105d |  | start no earlier than 2000-10-02 |  |  |  |
| 159 | 1.4.1.5 | Flex Hybrid FDR | milestone | 0d | 2000-12-15 | 2000-12-15 |  | 771d | 0d | start no earlier than 2000-12-15 |  |  |  |
| 160 | 1.4.1.6 | Flex 3.x Design |  | 170d | 2001-01-12 | 2001-09-06 | 159FS+20d | 771d | 0d | start no earlier than 2001-01-08 |  |  |  |
| 161 | 1.4.1.7 | Flex Preproduction Design |  | 120d | 2002-01-17 | 2002-07-03 | 124FS+60d | 437d | 0d | start no earlier than 2001-12-31 |  |  |  |
| 162 | 1.4.1.8 | Release Flex Bids | milestone | 0d | 2002-04-24 | 2002-04-24 | 163FF-30d | 897d |  |  |  |  |  |
| 163 | 1.4.1.9 | Flex Bid Evaluation Complete | milestone | 0d | 2002-06-05 | 2002-06-05 | 164FF-20d | 867d | 0d |  |  |  |  |
| 164 | 1.4.1.10 | Flex Hybrid PRR | milestone | 0d | 2002-07-03 | 2002-07-03 | 161 | 437d | 0d | start no earlier than 1999-10-01 |  |  |  |
| 165 | 1.4.1.11 | ATLAS PM Approval of Flex Proc | milestone | 0d | 2002-07-17 | 2002-07-17 | 164FS+10d | 437d | 0d |  |  |  |  |
| 166 | 1.4.1.12 | Release initial MC for flex hybrid and assembly | milestone | 0d | 2002-07-17 | 2002-07-17 | 165 | 837d |  |  |  |  |  |
| 167 | 1.4.1.13 | Award Flex Contracts | milestone | 0d | 2002-07-31 | 2002-07-31 | 165FS+10d | 437d | 0d |  |  |  |  |
| 168 | 1.4.1.14 | 1st Optical Prototype Design |  | 100d | 2000-10-02 | 2001-02-16 |  | 610d | 0d | start no earlier than 2000-10-02 |  |  |  |
| 169 | 1.4.1.15 | Optical package decision | milestone | 0d | 2001-06-15 | 2001-06-15 |  | 596d | 0d | start no earlier than 2001-06-15 |  |  |  |
| 170 | 1.4.1.16 | 2nd Optical Prototype Design |  | 80d | 2001-06-15 | 2001-10-04 | 182, 169 | 596d | 0d | start no earlier than 2001-02-19 |  |  |  |
| 171 | 1.4.1.17 | Optical FDR | milestone | 0d | 2002-01-31 | 2002-01-31 | 183FS+5d | 596d | 0d | start no earlier than 2001-08-31 |  |  |  |
| 172 | 1.4.1.18 | 3rd Optical Prototype Design |  | 90d | 2002-02-01 | 2002-06-06 | 171 | 596d | 0d | start no earlier than 2001-09-03 |  |  |  |
| 173 | 1.4.1.19 | Optical Preproduction Design |  | 60d | 2002-08-30 | 2002-11-21 | 184 | 746d |  | start no earlier than 2002-02-28 |  |  |  |
| 174 | 1.4.1.20 | Optical PRR | milestone | 0d | 2003-03-05 | 2003-03-05 | 184, 109 | 462d | 0d | start no earlier than 2002-02-15 |  |  |  |
| 175 | 1.4.1.21 | Release initial MC for optical components | milestone | 0d | 2003-03-19 | 2003-03-19 | 174FS+10d | 662d |  |  |  |  |  |

Notes:
- 140: Assumes Temic. 265 wafers required.
- 142: About 4 wafers per day all sites.

| ID | WBS | Task | Type | Duration | Start | Finish | Predecessors | Total slack | Free slack | Constraint | Resources | Work | Cost |
| --- | --- | --- | --- | --- | --- | --- | --- | --- | --- | --- | --- | --- | --- |
| 176 | 1.1.1.4.2 | **Development Prototypes** |  | 464d | 2001-01-08 | 2002-10-17 |  | 610d |  | start no earlier than 2000-07-18 |  | 1300h | 153,624 |
| 177 | 1.4.2.1 | Hybrids Protos FY01 $s |  | 190d | 2001-01-08 | 2001-09-28 |  | 1045d |  | start no earlier than 2001-01-08 | LBLs CL PRJ [6.6%]; LBLs SH PRJ [1.3%]; LBLs PM PRJ; UOK ST PRJ [28.9%]; UOK LW PRJ; OSU ST PRJ [6.6%]; OSU LW PRJ | 660h | 91,517.4 |
| 178 | 1.4.2.2 | Hybrids Protos FY02 $s |  | 261d | 2001-10-01 | 2002-09-30 |  | 784d |  | start no earlier than 2001-10-01 | LBLs CL PRJ [4.8%]; LBLs PM PRJ; UOK ST PRJ [21.1%]; UOK LW PRJ; OSU ST PRJ [4.8%]; OSU LW PRJ | 640h | 62,106.6 |
| 179 | 1.4.2.3 | Hybrids Protos Fy03 $s |  | 13d | 2002-10-01 | 2002-10-17 |  | 771d |  | start no earlier than 2002-10-01 |  |  |  |
| 180 | 1.4.2.4 | Flex 3.x Fab and Test |  | 380d | 2001-05-04 | 2002-10-17 | 160SS+80d | 771d | 0d |  |  |  |  |
| 181 | 1.4.2.5 | Initial Flex 3.x tests complete | milestone | 0d | 2001-12-13 | 2001-12-13 | 180SS+160d | 991d | 0d |  |  |  |  |
| 182 | 1.4.2.6 | 1st Optical Prototype Fab and Test |  | 100d | 2001-01-08 | 2001-05-25 | 168SS+70d | 610d | 14d |  |  |  |  |
| 183 | 1.4.2.7 | 2nd Optical Prototype Fab and Test |  | 90d | 2001-09-21 | 2002-01-24 | 170SS+70d | 596d | 0d |  |  |  |  |
| 184 | 1.4.2.8 | 3rd Optical Prototype Fab and Test |  | 90d | 2002-04-26 | 2002-08-29 | 172SS+60d | 596d | 0d |  |  |  |  |
| 185 | 1.1.1.4.3 | **Production** |  | 676d | 2001-12-13 | 2004-07-15 |  | 316d |  |  |  | 3520h | 293,994.5 |
| 186 | 1.4.3.1 | Hybrids Production FY02 $s |  | 208d | 2001-12-13 | 2002-09-30 |  | 784d |  | start no earlier than 2001-12-13 | SUNYA PM PRJ; UOK LW PRJ; OSU LW PRJ |  | 26,000 |
| 187 | 1.4.3.2 | Hybrids Production FY03 $s |  | 261d | 2002-10-01 | 2003-09-30 |  | 523d |  | start no earlier than 2002-10-01 | LBLs CL PRJ [13%]; LBLs PM PRJ; SUNYA ST PRJ [33.6%]; UOK ST PRJ [33.6%]; UOK ET PRJ [9.6%]; UOK HI PRJ; UOK LW PRJ; OSU ET PRJ [59.4%]; OSU ST PRJ [13.4%]; OSU LW PRJ | 3396h | 264,033.5 |
| 188 | 1.4.3.3 | Hybrids Production FY04 $s |  | 207d | 2003-10-01 | 2004-07-15 |  | 316d |  | start no earlier than 2003-10-01 | UOK ET PRJ [1.4%]; OSU ET PRJ [4.8%]; OSU ST PRJ [1.2%] | 124h | 3,961 |
| 189 | 1.4.3.4 | Start initial production buy of components | milestone | 0d | 2001-12-13 | 2001-12-13 | 181 | 991d |  | start no earlier than 1999-10-01 |  |  |  |
| 190 | 1.4.3.5 | Outer Flex Hybrid (Pre)Production/Load |  | 250d | 2002-08-01 | 2003-07-16 | 167 | 437d | 0d |  |  |  |  |
| 191 | 1.4.3.6 | First outer flex delivered | milestone | 0d | 2002-11-20 | 2002-11-20 | 190SS+80d | 437d | 0d |  |  |  |  |
| 192 | 1.4.3.7 | Outer flex testing |  | 250d | 2002-11-21 | 2003-11-05 | 191 | 437d | 0d |  |  |  |  |
| 193 | 1.4.3.8 | First outer flex available for module assembly | milestone | 0d | 2003-02-12 | 2003-02-12 | 191FS+60d | 687d |  |  |  |  |  |
| 194 | 1.4.3.9 | Need date for first outer flex | milestone | 0d | 2003-11-20 | 2003-11-20 | 234SS-10d | 487d |  |  |  |  |  |
| 195 | 1.4.3.10 | Outer flex testing complete | milestone | 0d | 2003-11-05 | 2003-11-05 | 192 | 437d | 0d |  |  |  |  |
| 196 | 1.4.3.11 | B-Layer Flex Hybrid (Pre)Production/Load/Test |  | 90d | 2003-08-14 | 2003-12-17 | 195FS-60d | 437d | 0d |  |  |  |  |
| 197 | 1.4.3.12 | First B-Layer flex delivered | milestone | 0d | 2003-11-05 | 2003-11-05 | 196SS+60d | 437d | 0d |  |  |  |  |
| 198 | 1.4.3.13 | First B-Layer flex available for modules | milestone | 0d | 2004-01-28 | 2004-01-28 | 197FS+60d | 437d |  |  |  |  |  |
| 199 | 1.4.3.14 | Need date for first B-layer flex | milestone | 0d | 2004-07-15 | 2004-07-15 | 241SS-10d | 317d |  |  |  |  |  |
| 200 | 1.4.3.15 | B-Layer flex testing complete | milestone | 0d | 2003-12-17 | 2003-12-17 | 196 | 467d |  |  |  |  |  |
| 201 | 1.4.3.16 | Optical (Pre)Production |  | 190d | 2003-04-03 | 2003-12-24 | 174FS+20d | 462d | 0d |  |  |  |  |
| 202 | 1.4.3.17 | First optical boards | milestone | 0d | 2003-08-20 | 2003-08-20 | 201SS+100d | 552d |  |  |  |  |  |
| 203 | 1.4.3.18 | Optical production complete | milestone | 0d | 2003-12-24 | 2003-12-24 | 201 | 462d |  |  |  |  |  |

| ID | WBS | Task | Type | Duration | Start | Finish | Predecessors | Total slack | Free slack | Constraint | Resources | Work | Cost |
| --- | --- | --- | --- | --- | --- | --- | --- | --- | --- | --- | --- | --- | --- |
| 205 | 1.1.1.5 | **Modules** |  | 855d | 2001-07-05 | 2004-10-13 |  | 252d |  |  |  | 20603h | 923,605.21 |
| 206 | 1.1.1.5.1 | **Design** |  | 576d | 2001-07-26 | 2003-10-09 |  | 516d |  |  |  | 2200h | 126,191.6 |
| 207 | 1.5.1.1 | Modules Design FY01 $s |  | 47d | 2001-07-26 | 2001-09-28 |  | 1045d |  | start no earlier than 2001-07-26 | LBLj DS PRJ [117%]; LBLj EE PRJ [234%]; LBLj TR PRJ | 1320h | 78,704.8 |
| 208 | 1.5.1.2 | Modules Design FY02 $s |  | 261d | 2001-10-01 | 2002-09-30 |  | 784d |  | start no earlier than 2001-10-01 | LBLj DS PRJ [21.1%]; LBLj EE PRJ [21.1%]; LBLj TR PRJ | 880h | 47,486.8 |
| 209 | 1.5.1.3 | Modules Design FY03 $s |  | 212d | 2002-10-01 | 2003-07-23 |  | 572d |  | start no earlier than 2002-10-01 |  |  |  |
| 210 | 1.5.1.4 | Prototype tooling/assembly design |  | 240d | 2001-07-26 | 2002-06-26 | 211FF | 852d |  | start no earlier than 2000-10-02 |  |  |  |
| 211 | 1.5.1.5 | Bare module PRR | milestone | 0d | 2002-06-26 | 2002-06-26 | 122FS+120d, 93 | 852d | 0d | start no earlier than 2001-08-31 |  |  |  |
| 212 | 1.5.1.6 | Module assembly FDR | milestone | 0d | 2002-06-26 | 2002-06-26 | 211 | 852d |  |  |  |  |  |
| 213 | 1.5.1.7 | Production tooling/assembly design |  | 138d | 2002-11-18 | 2003-05-28 | 214FF | 612d |  |  |  |  |  |
| 214 | 1.5.1.8 | Module assembly PRR | milestone | 0d | 2003-05-28 | 2003-05-28 | 96FS+60d | 572d | 0d |  |  |  |  |
| 215 | 1.5.1.9 | Release initial MC for FE die sort | milestone | 0d | 2003-06-25 | 2003-06-25 | 214FS+20d | 592d |  |  |  |  |  |
| 216 | 1.5.1.10 | Production module tooling complete | milestone | 0d | 2003-07-23 | 2003-07-23 | 214FS+40d | 572d |  |  |  |  |  |
| 217 | 1.5.1.11 | Need date for production module tooling |  | 1d | 2003-10-09 | 2003-10-09 | 234SS-40d | 516d |  |  |  |  |  |
| 218 | 1.1.1.5.2 | **Development/Prototypes** |  | 495d | 2001-07-05 | 2003-05-28 |  | 612d |  |  |  | 4156h | 261,240 |
| 219 | 1.5.2.1 | Modules Protos FY01 $s |  | 62d | 2001-07-05 | 2001-09-28 |  | 1045d |  | start no earlier than 2001-07-05 | LBLj MT PRJ [26.6%]; LBLj TS PRJ [18.1%]; LBLj PM PRJ; LBLj S PRJ; LBLs PM PRJ | 222h | 80,538.24 |
| 220 | 1.5.2.2 | Modules Protos FY02 $s |  | 261d | 2001-10-01 | 2002-09-30 |  | 784d |  | start no earlier than 2001-10-01 | LBLj ET PRJ [21.1%]; LBLj MT PRJ [25.3%]; LBLj SH PRJ [50.4%]; LBLj TS PRJ [4.3%]; LBLj PM PRJ; LBLj S PRJ; LBLs ST PRJ [3.6%]; LBLs SH PRJ [1%]; LBLs PM PRJ | 2206h | 134,647 |
| 221 | 1.5.2.3 | Modules Protos FY03 $s |  | 172d | 2002-10-01 | 2003-05-28 |  | 612d |  | start no earlier than 2002-10-01 | LBLj ET PRJ [16%]; LBLj MT PRJ [38.4%]; LBLj ST PRJ [64%]; LBLj S PRJ; LBLs ST PRJ [7.3%]; LBLs PM PRJ | 1728h | 46,054.76 |
| 222 | 1.5.2.4 | Dummy/prototype module fab/test |  | 495d | 2001-07-05 | 2003-05-28 | 214FF | 612d |  | start no earlier than 2000-10-02 |  |  |  |
| 223 | 1.1.1.5.3 | **Production** |  | 295d | 2003-08-28 | 2004-10-13 |  | 142d |  |  |  | 14247h | 536,173.61 |
| 224 | 1.5.3.1 | Modules Production FY03 $s |  | 24d | 2003-08-28 | 2003-09-30 |  | 523d |  | start no earlier than 2003-08-28 | LBLj ST PRJ [1947.9%]; LBLj PM PRJ; LBLs CL PRJ [916.7%]; LBLs ET PRJ [93.8%]; LBLs MT PRJ [93.8%]; LBLs SH PRJ [156.8%]; LBLs ST PRJ [916.7%]; LBLs PM PRJ; OSU CL PRJ [306.8%]; OSU MT PRJ [306.8%]; OSU LW PRJ | 9099h | 345,935.98 |
| 225 | 1.5.3.2 | Modules Production FY04 $s |  | 262d | 2003-10-01 | 2004-09-30 |  | 261d |  | start no earlier than 2003-10-01 | LBLj ST PRJ [94.5%]; LBLj PM PRJ; LBLs CL PRJ [28.1%]; LBLs ET PRJ [33.4%]; LBLs MT PRJ [33.4%]; LBLs ST PRJ [28.1%]; LBLs PM PRJ; OSU CL PRJ [14.1%]; OSU MT PRJ [14.1%]; OSU LW PRJ | 5148h | 190,237.63 |
| 226 | 1.5.3.3 | Modules Production FY05 $s |  | 9d | 2004-10-01 | 2004-10-13 |  | 252d |  | start no earlier than 2004-10-01 |  |  |  |
| 227 | 1.5.3.4 | IBM FE Bump Deposition |  | 230d | 2003-08-28 | 2004-07-14 | 142SS+20d | 142d | 0d |  |  |  |  |
| 228 | 1.5.3.5 | IBM FE wafer thinning |  | 230d | 2003-09-25 | 2004-08-11 | 227SS+20d | 142d | 0d |  |  |  |  |
| 229 | 1.5.3.6 | IBM FE Wafer Dicing |  | 230d | 2003-10-02 | 2004-08-18 | 228SS+5d | 142d | 0d |  |  |  |  |
| 230 | 1.5.3.7 | IBM FE Die sort |  | 230d | 2003-10-09 | 2004-08-25 | 229SS+5d | 142d | 0d |  |  |  |  |
| 231 | Sil L2/8 | Start IBM outer bare module production | milestone | 0d | 2003-10-22 | 2003-10-22 | 230SS+10d | 142d | 0d |  |  |  |  |
| 232 | 1.5.3.9 | IBM Outer bare module production |  | 180d | 2003-10-23 | 2004-06-30 | 231 | 142d | 0d |  |  |  |  |
| 233 | 1.5.3.10 | IBM outer bare module testing |  | 165d | 2003-11-20 | 2004-07-07 | 232SS+20d | 142d | 0d |  |  |  |  |
| 234 | 1.5.3.11 | IBM outer module assembly/test |  | 165d | 2003-12-04 | 2004-07-21 | 233SS+10d | 142d | 0d |  |  |  |  |
| 235 | 1.5.3.12 | Complete testing IBM outer modules | milestone | 0d | 2004-07-21 | 2004-07-21 | 234 | 312d |  |  |  |  |  |
| 236 | 1.5.3.13 | Module attach to disk sectors |  | 160d | 2003-12-18 | 2004-07-28 | 37SS+120d, 234SS+10d | 142d | 0d |  |  |  |  |
| 237 | 1.5.3.14 | Test disk sectors |  | 160d | 2003-12-25 | 2004-08-04 | 236SS+5d | 142d | 0d |  |  |  |  |
| 238 | 1.5.3.15 | Complete testing disk sectors | milestone | 0d | 2004-08-04 | 2004-08-04 | 237 | 302d |  |  |  |  |  |
| 239 | 1.5.3.16 | Start B-Layer bare module production | milestone | 0d | 2004-07-14 | 2004-07-14 | 146SS+70d | 252d | 0d |  |  |  |  |
| 240 | 1.5.3.17 | B-Layer bare module production |  | 55d | 2004-07-15 | 2004-09-29 | 239 | 252d | 0d |  |  |  |  |
| 241 | 1.5.3.18 | B-Layer module assembly/test |  | 55d | 2004-07-29 | 2004-10-13 | 240SS+10d | 252d | 0d | start no earlier than 2003-10-20 |  |  |  |
| 242 | 1.5.3.19 | Complete testing B-Layer modules | milestone | 0d | 2004-10-13 | 2004-10-13 | 241 | 252d |  |  |  |  |  |

Notes:
- 227: Includes B-layer
- 228: Includes B-layer
- 229: Includes B-layer
- 230: Includes B-layer
- 232: About 35 modules per week. Peak rate from two vendors is expected to be 40 modules per week.
- 233: About 35 modules per week.
- 234: About 35 modules per week.
- 236: About one sector every four days. This is about 1/2 of expected rate.
- 237: About one sector every four days. This is about 1/2 of expected rate.
- 240: About 35 modules per week. Peak rate from two vendors is expected to be 40 modules per week.
- 241: About 35 modules per week. Peak rate from two vendors is expected to be 40 modules per week.

| ID | WBS | Task | Duration | Start | Finish | Total slack | Constraint | Resources | Cost |
| --- | --- | --- | --- | --- | --- | --- | --- | --- | --- |
| 244 | 1.1.1.6 | **Beam/System Test Support** | 1305d | 2000-10-02 | 2005-09-30 | 0d |  |  | 116,865 |
| 245 | 1.6.1 | **Test Beam Support** | 780d | 2000-10-02 | 2003-09-26 | 525d |  |  | 44,520 |
| 246 | 1.6.1.1 | Test Beam Support FY01 $s | 260d | 2000-10-02 | 2001-09-28 | 1045d | start no earlier than 2000-10-02 | LBLj PM PRJ | 11,130 |
| 247 | 1.6.1.2 | Test Beam Support FY02 $s | 261d | 2001-10-01 | 2002-09-30 | 784d | start no earlier than 2001-10-01 | LBLj PM PRJ | 16,695 |
| 248 | 1.6.1.3 | Test Beam Support FY03 $s | 259d | 2002-10-01 | 2003-09-26 | 525d | start no earlier than 2002-10-01 | LBLj PM PRJ | 16,695 |
| 249 | 1.6.2 | **System Test Support** | 1305d | 2000-10-02 | 2005-09-30 | 0d |  |  | 72,345 |
| 250 | 1.6.2.1 | System Test Support FY01 $s | 260d | 2000-10-02 | 2001-09-28 | 1045d | start no earlier than 2000-10-02 | LBLj PM PRJ | 16,695 |
| 251 | 1.6.2.2 | System Test Support FY02 $s | 261d | 2001-10-01 | 2002-09-30 | 784d | start no earlier than 2001-10-01 | LBLj PM PRJ | 16,695 |
| 252 | 1.6.2.3 | System Test Support FY03 $s | 261d | 2002-10-01 | 2003-09-30 | 523d | start no earlier than 2002-10-01 | LBLj PM PRJ | 16,695 |
| 253 | 1.6.2.4 | System Test Support FY04$s | 262d | 2003-10-01 | 2004-09-30 | 261d | start no earlier than 2003-10-01 | LBLj PM PRJ | 11,130 |
| 254 | 1.6.2.5 | System Test Support FY05 $s | 261d | 2004-10-01 | 2005-09-30 | 0d | start no earlier than 2004-10-01 | LBLj PM PRJ | 11,130 |
