# Pixel_mechanics

Schedule from MS Project, 1999-10-01 to 2006-04-03, costs in $.
LBNL

## Calendars

- Standard: Mon-Fri 08:00-12:00, 13:00-17:00; Sat-Sun off.

## Resources

| Resource | Group | Rate |
| --- | --- | --- |
| LBLj SP PRJ | LBL | 67.53 |
| LBLj EE PRJ | LBL | 70.95 |
| LBLj ME PRJ | LBL | 70.95 |
| LBLj DS PRJ | LBL | 31.52 |
| LBLj ET PRJ | LBL | 31.52 |
| LBLj MT PRJ | LBL | 31.52 |
| LBLj AS PRJ | LBL | 30.01 |
| LBLj OA PRJ | LBL | 30.01 |
| LBLj CL PRJ | LBL | 20.02 |
| LBLj SH PRJ | LBL | 52.44 |
| LBLj TS PRJ | LBL | 52.44 |
| LBLj ST PRJ | LBL | 15.11 |
| LBLj PM PRJ | LBL | 0.11 |
| LBLj S PRJ | LBL |  |
| LBLj TR PRJ | LBL | 0.11 |
| LBLj LW PRJ | LBL | 0.11 |
| LBLj RD PRJ | LBL | 0.05 |
| LBLj HI PRJ | LBL | 0.05 |
| LBLs SP PRJ | LBL | 100 |
| LBLs EE PRJ | LBL | 105.06 |
| LBLs ME PRJ | LBL | 105.06 |
| LBLs DS PRJ | LBL | 49.96 |
| LBLs ET PRJ | LBL | 49.96 |
| LBLs MT PRJ | LBL | 49.96 |
| LBLs AS PRJ | LBL | 47.56 |
| LBLs OA PRJ | LBL | 47.56 |
| LBLs CL PRJ | LBL | 22.06 |
| LBLs SH PRJ | LBL | 52.44 |
| LBLs TS PRJ | LBL | 49.91 |
| LBLs ST PRJ | LBL | 15.11 |
| LBLs PM PRJ | LBL | 0.11 |
| LBLs S PRJ | LBL |  |
| LBLs TR PRJ | LBL | 0.11 |
| LBLs LW PRJ | LBL | 0.11 |
| LBLs RD PRJ | LBL | 0.05 |
| LBLs HI PRJ | LBL | 0.05 |
| SUNYA SP PRJ | SUNYA |  |
| SUNYA EE PRJ | SUNYA |  |
| SUNYA ME PRJ | SUNYA |  |
| SUNYA DS PRJ | SUNYA | 27.93 |
| SUNYA ET PRJ | SUNYA | 27.93 |
| SUNYA MT PRJ | SUNYA | 27.93 |
| SUNYA AS PRJ | SUNYA | 27.93 |
| SUNYA OA PRJ | SUNYA | 27.93 |
| SUNYA CL PRJ | SUNYA |  |
| SUNYA SH PRJ | SUNYA | 27.93 |
| SUNYA TS PRJ | SUNYA | 27.93 |
| SUNYA ST PRJ | SUNYA | 14.7 |
| SUNYA PM PRJ | SUNYA |  |
| SUNYA S PRJ | SUNYA |  |
| SUNYA TR PRJ | SUNYA |  |
| SUNYA LW PRJ | SUNYA |  |
| SUNYA RD PRJ | SUNYA | 0.47 |
| SUNYA HI PRJ | SUNYA |  |
| UNM SP PRJ | UNM | 40.32 |
| UNM EE PRJ | UNM | 43.95 |
| UNM ME PRJ | UNM | 40.32 |
| UNM DS PRJ | UNM | 22.68 |
| UNM ET PRJ | UNM | 22.68 |
| UNM MT PRJ | UNM | 22.68 |
| UNM AS PRJ | UNM | 22.68 |
| UNM OA PRJ | UNM | 22.68 |
| UNM CL PRJ | UNM | 18.9 |
| UNM SH PRJ | UNM | 49.14 |
| UNM TS PRJ | UNM | 49.14 |
| UNM ST PRJ | UNM | 10.99 |
| UNM PM PRJ | UNM |  |
| UNM S PRJ | UNM |  |
| UNM TR PRJ | UNM |  |
| UNM LW PRJ | UNM |  |
| UNM RD PRJ | UNM |  |
| UNM HI PRJ | UNM |  |
| UOK SP PRJ | UOK | 45.57 |
| UOK EE PRJ | UOK | 45.57 |
| UOK ME PRJ | UOK | 45.57 |
| UOK DS PRJ | UOK | 31.6 |
| UOK ET PRJ | UOK | 33.7 |
| UOK MT PRJ | UOK | 31.6 |
| UOK AS PRJ | UOK | 31.6 |
| UOK OA PRJ | UOK | 31.6 |
| UOK CL PRJ | UOK | 13.23 |
| UOK SH PRJ | UOK | 13.23 |
| UOK TS PRJ | UOK | 13.23 |
| UOK ST PRJ | UOK | 10.99 |
| UOK PM PRJ | UOK |  |
| UOK S PRJ | UOK |  |
| UOK TR PRJ | UOK | 0.15 |
| UOK LW PRJ | UOK |  |
| UOK RD PRJ | UOK |  |
| UOK HI PRJ | UOK |  |
| OSU PM PRJ | OSU |  |
| OSU LW PRJ | OSU |  |
| OSU ST PRJ | OSU | 11.61 |
| OSU ET PRJ | OSU | 36.5 |
| OSU EE PRJ | OSU | 66.36 |
| OSU CL PRJ | OSU | 21.56 |
| OSU MT PRJ | OSU | 36.5 |
| OSU HI PRJ | OSU |  |

## Schedule

| ID | WBS | Task | Type | Duration | Start | Finish | Predecessors | Total slack | Free slack | Constraint | Resources | Work | Cost |
| --- | --- | --- | --- | --- | --- | --- | --- | --- | --- | --- | --- | --- | --- |
| 1 | 1.1.1 | **US ATLAS Pixel Project** |  | 1696d | 1999-10-01 | 2006-04-03 |  | 0d |  |  |  | 67099h | 6,381,669.33 |
| 2 | 1.1.1.1 | **Mechanics** |  | 1435d | 2000-10-02 | 2006-04-03 |  | 0d |  |  |  | 22266h | 3,067,108.16 |
| 3 | 1.1.1.1.1 | **Design** |  | 1185d | 2000-10-02 | 2005-04-15 |  | 250d |  |  |  | 12320h | 1,375,240.2 |
| 4 | 1.1.1.1 | Mechanics Engineering FY01 $s |  | 260d | 2000-10-02 | 2001-09-28 |  | 1175d |  | start no earlier than 2000-10-02 | UNM EE PRJ [42.3%]; UNM TR PRJ; LBLj DS PRJ [63.5%]; LBLj ME PRJ [84.6%]; LBLj TR PRJ; LBLj PM PRJ; LBLs PM PRJ; LBLs DS PRJ [10.6%] | 4180h | 571,176.6 |
| 5 | 1.1.1.2 | Mechanics Engineering FY02 $s |  | 261d | 2001-10-01 | 2002-09-30 |  | 914d |  | start no earlier than 2001-10-01 | LBLj DS PRJ [42.1%]; LBLj ME PRJ [84.3%]; LBLj EE PRJ [42.1%]; LBLj TR PRJ; LBLs DS PRJ [10.5%]; LBLs PM PRJ; LBLs TR PRJ | 3740h | 447,304.8 |
| 6 | 1.1.1.3 | Mechanics Engineering FY03 $s |  | 261d | 2002-10-01 | 2003-09-30 |  | 653d |  | start no earlier than 2002-10-01 | LBLj DS PRJ [42.1%]; LBLj ME PRJ [84.3%]; LBLj EE PRJ [21.1%]; LBLj TR PRJ; LBLs DS PRJ [21.1%]; LBLs PM PRJ; LBLs TR PRJ | 3520h | 261,872 |
| 7 | 1.1.1.4 | Mechanics Engineering FY04 $s |  | 262d | 2003-10-01 | 2004-09-30 |  | 391d |  | start no earlier than 2003-10-01 | LBLj DS PRJ [21%]; LBLj ME PRJ [21%]; LBLj TR PRJ; LBLs TR PRJ | 880h | 82,886.8 |
| 8 | 1.1.1.5 | Mechanics Engineering FY05 $s |  | 141d | 2004-10-01 | 2005-04-15 |  | 250d |  | start no earlier than 2004-10-01 | LBLs TR PRJ |  | 12,000 |
| 9 | 1.1.1.6 | Release bids for global support | milestone | 0d | 2002-02-26 | 2002-02-26 | 11 | 1044d | 0d |  |  |  |  |
| 10 | 1.1.1.7 | Bid evaluation complete for support | milestone | 0d | 2002-03-25 | 2002-03-25 | 9FS+20d | 1044d | 0d |  |  |  |  |
| 11 | 1.1.1.8 | Global Support PRR | milestone | 0d | 2002-02-26 | 2002-02-26 |  | 659d | 0d | start no earlier than 2002-02-26 |  |  |  |
| 12 | 1.1.1.9 | ATLAS PM approval of global support procurement | milestone | 0d | 2002-04-01 | 2002-04-01 | 10FS+5d | 1044d |  |  |  |  |  |
| 13 | 1.1.1.10 | Support tube FDR | milestone | 0d | 2002-06-17 | 2002-06-17 |  | 990d | 0d | start no earlier than 2002-06-17 |  |  |  |
| 14 | 1.1.1.11 | Support tube PRR | milestone | 0d | 2002-12-16 | 2002-12-16 |  | 595d | 0d | start no earlier than 2002-12-16 |  |  |  |
| 15 | 1.1.1.12 | Cables/services FDR | milestone | 0d | 2002-06-17 | 2002-06-17 | 13 | 990d |  | start no earlier than 2001-09-03 |  |  |  |
| 16 | 1.1.1.13 | Release bids for initial cables | milestone | 0d | 2002-12-06 | 2002-12-06 | 17FF-40d | 865d |  |  |  |  |  |
| 17 | 1.1.1.14 | Bid evaluation complete for outer cables | milestone | 0d | 2003-01-31 | 2003-01-31 | 18FF-10d | 825d | 0d |  |  |  |  |
| 18 | 1.1.1.15 | Cables/services PRR | milestone | 0d | 2003-02-17 | 2003-02-17 |  | 255d | 0d | start no earlier than 2003-02-17 |  |  |  |
| 19 | 1.1.1.16 | ATLAS PM approval of outer cables procurement | milestone | 0d | 2003-02-21 | 2003-02-21 | 18FS+5d | 810d |  |  |  |  |  |
| 20 | 1.1.1.17 | Assembly/Installation CDR | milestone | 0d | 2002-02-26 | 2002-02-26 | 11 | 1069d |  |  |  |  |  |
| 21 | 1.1.1.18 | Assembly/Installation FDR | milestone | 0d | 2002-12-16 | 2002-12-16 |  | 860d |  | start no earlier than 2002-12-16 |  |  |  |
| 22 | 1.1.1.19 | Assembly/Installation PRR | milestone | 0d | 2003-06-16 | 2003-06-16 |  | 465d | 0d | start no earlier than 2003-06-16 |  |  |  |
| 23 | 1.1.1.1.2 | **Development/Prototypes** |  | 707d | 2000-10-02 | 2003-06-17 |  | 728d |  |  |  | 1713h | 256,964.76 |
| 24 | 1.1.2.1 | Development/Prototypes FY01 $s |  | 260d | 2000-10-02 | 2001-09-28 |  | 1175d |  | start no earlier than 2000-10-02 | LBLs MT PRJ [10.6%]; LBLs ET PRJ [4.8%]; LBLs SH PRJ [33.9%]; LBLs PM PRJ; LBLj SH PRJ [10.2%]; LBLj PM PRJ | 1237h | 152,236.68 |
| 25 | 1.1.2.2 | Development/Prototypes FY02 $s |  | 261d | 2001-10-01 | 2002-09-30 |  | 914d |  | start no earlier than 2001-10-01 | LBLs ET PRJ [3.9%]; LBLs SH PRJ [14.1%]; LBLs PM PRJ; LBLj SH PRJ [4.8%]; LBLj PM PRJ | 476h | 104,728.08 |
| 26 | 1.1.2.3 | Development/Prototypes FY03 $s |  | 186d | 2002-10-01 | 2003-06-17 |  | 728d |  | start no earlier than 2002-10-01 |  |  |  |
| 27 | 1.1.2.4 | Support tube development/prototypes |  | 240d | 2001-07-16 | 2002-06-17 | 13FF | 990d | 0d |  |  |  |  |
| 28 | 1.1.2.5 | Support tube development complete | milestone | 0d | 2002-06-17 | 2002-06-17 | 27 | 990d |  |  |  |  |  |
| 29 | 1.1.2.6 | Outer services development/prototypes |  | 400d | 2001-08-06 | 2003-02-17 | 18FF | 815d | 0d | start no earlier than 2000-10-02 |  |  |  |
| 30 | 1.1.2.7 | Compl. Outer services development/prototypes | milestone | 0d | 2003-02-17 | 2003-02-17 | 29 | 815d |  |  |  |  |  |

| ID | WBS | Task | Type | Duration | Start | Finish | Predecessors | Total slack | Free slack | Constraint | Resources | Work | Cost |
| --- | --- | --- | --- | --- | --- | --- | --- | --- | --- | --- | --- | --- | --- |
| 31 | 1.1.1.1.3 | **Production** |  | 1233d | 2001-07-11 | 2006-04-03 |  | 0d |  |  |  | 8233h | 1,434,903.2 |
| 32 | 1.1.3.1 | Production FY01 $s |  | 58d | 2001-07-11 | 2001-09-28 |  | 1175d |  | start no earlier than 2001-07-11 | LBLs HI PRJ; LBLs PM PRJ; LBLj MT PRJ [189.7%]; LBLj SH PRJ [108%]; LBLj PM PRJ | 1381h | 199,276.04 |
| 33 | 1.1.3.2 | Production FY02 $s |  | 261d | 2001-10-01 | 2002-09-30 |  | 914d |  | start no earlier than 2001-10-01 | LBLs ET PRJ; LBLs MT PRJ; LBLs SH PRJ; LBLs HI PRJ; LBLs PM PRJ; LBLj MT PRJ [42.1%] | 1377h | 365,328.12 |
| 34 | 1.1.3.3 | Production FY03 $s |  | 261d | 2002-10-01 | 2003-09-30 |  | 653d |  | start no earlier than 2002-10-01 | LBLs ET PRJ [62.1%]; LBLs MT PRJ [27.9%]; LBLs SH PRJ [128.2%]; LBLs HI PRJ; LBLs PM PRJ; LBLs S PRJ; LBLj ET PRJ [17.3%]; LBLj SH PRJ [11.1%]; LBLj PM PRJ | 5149h | 769,799.6 |
| 35 | 1.1.3.4 | Production FY04 $s |  | 262d | 2003-10-01 | 2004-09-30 |  | 391d |  | start no earlier than 2003-10-01 | LBLs SH PRJ [15.6%]; LBLs PM PRJ; LBLs S PRJ | 326h | 93,821.44 |
| 36 | 1.1.3.5 | Production FY05 $s |  | 141d | 2004-10-01 | 2005-04-15 |  | 250d |  | start no earlier than 2004-10-01 | LBLs PM PRJ |  | 6,678 |
| 37 | 1.1.3.6 | Disk Sector Fab/Test |  | 260d | 2001-10-01 | 2002-09-27 |  | 730d | 529d | start no earlier than 2001-10-01 |  |  |  |
| 38 | 1.1.3.7 | Disk Support Ring Fab/Test |  | 260d | 2001-10-01 | 2002-09-27 |  | 915d |  | start no earlier than 2001-10-01 |  |  |  |
| 39 | 1.1.3.8 | Support Frame Fab/Test |  | 260d | 2002-04-09 | 2003-04-07 | 11FS+30d | 659d | 0d | start no earlier than 2000-11-16 |  |  |  |
| 40 | 1.1.3.9 | Support tubes Fab/Test |  | 265d | 2002-12-16 | 2003-12-19 | 14 | 595d |  | start no earlier than 2001-10-15 |  |  |  |
| 41 | 1.1.3.10 | Outer Services Fab/Test |  | 530d | 2003-03-31 | 2005-04-08 | 18FS+30d | 255d | 0d |  |  |  |  |
| 42 | 1.1.3.11 | All Outer Services Complete | milestone | 0d | 2005-04-08 | 2005-04-08 | 41 | 255d |  |  |  |  |  |
| 43 | 1.1.3.12 | Trial Outer Structure Assembly |  | 120d | 2003-04-08 | 2003-09-22 | 39 | 659d | 0d | start no earlier than 2001-08-03 |  |  |  |
| 44 | 1.1.3.13 | Outer Structure Complete/Ready for Modules | milestone | 0d | 2003-09-22 | 2003-09-22 | 43 | 659d |  |  |  |  |  |
| 45 | 1.1.3.14 | Outer Structure Needed for Modules | milestone | 0d | 2004-04-15 | 2004-04-15 | 224SS+10d | 511d |  |  |  |  |  |
| 46 | 1.1.3.15 | Disk Assembly/Test |  | 180d | 2004-04-16 | 2004-12-23 | 224SS+10d | 201d | 0d |  |  |  |  |
| 47 | Sil L2/9; Sil L3/1 | Disk System at CERN | milestone | 0d | 2005-01-20 | 2005-01-20 | 46FS+20d | 201d | 0d | start no earlier than 2003-04-03 |  |  |  |
| 48 | 1.1.3.17 | Fab services supports |  | 200d | 2003-07-14 | 2004-04-16 | 22FS+20d | 465d | 0d |  |  |  |  |
| 49 | 1.1.3.18 | Trial assembly services supports |  | 45d | 2004-04-19 | 2004-06-18 | 48 | 465d |  |  |  |  |  |
| 50 | 1.1.3.19 | Outer System Assembly/Test at CERN |  | 110d | 2005-01-21 | 2005-06-23 | 47 | 201d | 0d |  |  |  |  |
| 51 | 1.1.3.20 | Outer System Ready for Installation | milestone | 0d | 2005-06-23 | 2005-06-23 | 50 | 201d |  |  |  |  |  |
| 52 | 1.1.3.21 | ATLAS need date for installation for pilot run | milestone | 0d | 2005-02-24 | 2005-02-24 |  | 287d |  | start no earlier than 2005-02-24 |  |  |  |
| 53 | 1.1.3.22 | ATLAS need date for 1st physics run | milestone | 0d | 2006-04-03 | 2006-04-03 |  | 0d |  | start no earlier than 2006-04-03 |  |  |  |
| 55 | 1.1.1.2 | **Sensors** |  | 1059d | 2000-10-02 | 2004-10-21 |  | 376d |  |  |  | 3798h | 132,610.5 |
| 56 | 1.1.1.2.1 | **Design** |  | 760d | 2000-10-30 | 2003-09-26 |  | 655d |  |  |  | 1598h | 70,232.1 |
| 57 | 1.2.1.1 | Sensors Design FY01 $s |  | 240d | 2000-10-30 | 2001-09-28 |  | 1175d |  | start no earlier than 2000-10-30 | UNM EE PRJ [41.6%] | 799h | 35,116.05 |
| 58 | 1.2.1.2 | Sensors Design FY02 $s |  | 80d | 2001-10-01 | 2002-01-18 |  | 1095d |  | start no earlier than 2001-10-01 | UNM EE PRJ [124.8%] | 799h | 35,116.05 |
| 59 | 1.2.1.3 | Test Support |  | 520d | 2001-10-01 | 2003-09-26 |  | 655d |  | start no earlier than 2001-10-01 |  |  |  |
| 60 | 1.2.1.4 | ATLAS PM approval of production procurement | milestone | 0d | 2001-12-17 | 2001-12-17 | 67SS-15d | 1120d | 0d |  |  |  |  |
| 61 | 1.2.1.5 | Release initial MC for sensors/testing | milestone | 0d | 2001-12-17 | 2001-12-17 | 60 | 1120d |  |  |  |  |  |

Notes:
- 43: Trial assembly of frame sections and disk rings. B-layer structures not ready.
- 46: Disk is assembled as sectors are completed and tested. Disks inserted in frame as completed.
- 52: This is estimate. Final installation schedule not firm.

| ID | WBS | Task | Type | Duration | Start | Finish | Predecessors | Total slack | Free slack | Constraint | Resources | Work | Cost |
| --- | --- | --- | --- | --- | --- | --- | --- | --- | --- | --- | --- | --- | --- |
| 62 | 1.1.1.2.3 | **Production** |  | 1059d | 2000-10-02 | 2004-10-21 |  | 376d |  |  |  | 2200h | 62,378.4 |
| 63 | 1.2.2.1 | Sensors Production FY01 $s |  | 260d | 2000-10-02 | 2001-09-28 |  | 1175d |  | start no earlier than 2000-10-02 | SUNYA PM PRJ; UNM EE PRJ; UNM PM PRJ; UNM ST PRJ [84.6%] | 2200h | 62,378.4 |
| 64 | 1.2.2.2 | Sensors Production FY02 $s |  | 261d | 2001-10-01 | 2002-09-30 |  | 914d |  | start no earlier than 2001-10-01 |  |  |  |
| 65 | 1.2.2.3 | Sensors Production FY03 $s |  | 261d | 2002-10-01 | 2003-09-30 |  | 653d |  | start no earlier than 2002-10-01 |  |  |  |
| 66 | 1.2.2.4 | Sensors Production FY04 $s |  | 3d | 2003-10-01 | 2003-10-03 |  | 650d |  | start no earlier than 2003-10-01 |  |  |  |
| 67 | 1.2.2.5 | Sensors Production |  | 350d | 2002-01-07 | 2003-05-09 |  | 655d | 0d | start no earlier than 2002-01-07 |  |  |  |
| 68 | 1.2.2.6 | First production wafers delivered | milestone | 0d | 2002-05-24 | 2002-05-24 | 67SS+100d | 655d | 0d |  |  |  |  |
| 69 | 1.2.2.7 | Sensors 10% production complete | milestone | 0d | 2002-07-01 | 2002-07-01 |  | 980d |  | start no earlier than 2002-07-01 |  |  |  |
| 70 | 1.2.2.8 | Sensors 25% production complete | milestone | 0d | 2002-12-16 | 2002-12-16 |  | 860d |  | start no earlier than 2002-12-16 |  |  |  |
| 71 | 1.2.2.9 | Sensors 50% production complete | milestone | 0d | 2003-02-17 | 2003-02-17 |  | 815d |  | start no earlier than 2003-02-17 |  |  |  |
| 72 | 1.2.2.10 | Sensors Testing |  | 350d | 2002-05-27 | 2003-09-26 | 68 | 655d | 0d |  |  |  |  |
| 73 | 1.2.2.11 | Sensors Testing Complete | milestone | 0d | 2003-09-26 | 2003-09-26 | 72 | 655d |  |  |  |  |  |
| 74 | 1.2.2.12 | Sensors Need to Begin Module Production | milestone | 0d | 2003-11-07 | 2003-11-07 | 135SS | 626d |  |  |  |  |  |
| 75 | 1.2.2.13 | B-Layer Production |  | 125d | 2002-11-15 | 2003-05-08 |  | 656d | 0d | start no earlier than 2002-11-15 |  |  |  |
| 76 | 1.2.2.14 | First B-layer wafers delivered | milestone | 0d | 2003-04-03 | 2003-04-03 | 75SS+100d | 656d | 0d |  |  |  |  |
| 77 | 1.2.2.15 | B-layer sensor testing |  | 125d | 2003-04-04 | 2003-09-25 | 76 | 656d |  |  |  |  |  |
| 78 | 1.2.2.16 | B-layer sensors needed to begin modules | milestone | 0d | 2004-10-21 | 2004-10-21 | 226 | 376d |  |  |  |  |  |
| 80 | 1.1.1.3 | **Electronics** |  | 1320d | 1999-10-01 | 2004-10-21 |  | 376d |  |  |  | 12532h | 1,616,495.96 |
| 81 | 1.1.1.3.1 | **Design** |  | 1155d | 1999-10-01 | 2004-03-04 |  | 541d |  |  |  | 9592h | 988,642.56 |
| 82 | 1.3.1.1 | Elec.'s Design FY01 $s |  | 260d | 2000-10-02 | 2001-09-28 |  | 1175d |  | start no earlier than 2000-10-02 | LBLs EE PRJ [114.2%]; LBLs TR PRJ; LBLj EE PRJ [50.8%]; LBLj TR PRJ; OSU EE PRJ [21.1%] | 3872h | 381,344.16 |
| 83 | 1.3.1.2 | Elec.'s Design FY02 $s |  | 261d | 2001-10-01 | 2002-09-30 |  | 914d |  | start no earlier than 2001-10-01 | LBLs EE PRJ [147.5%]; LBLs TR PRJ; LBLj EE PRJ [42.1%]; LBLj TR PRJ; OSU EE PRJ [21.1%] | 4400h | 445,819.2 |
| 84 | 1.3.1.3 | Elec.'s Design FY03 $s |  | 261d | 2002-10-01 | 2003-09-30 |  | 653d |  | start no earlier than 2002-10-01 | LBLs EE PRJ [63.2%]; LBLs TR PRJ; LBLj TR PRJ | 1320h | 161,479.2 |
| 85 | 1.3.1.4 | Elec.'s Design FY04 $s |  | 41d | 2003-10-01 | 2003-11-26 |  | 612d |  | start no earlier than 2003-10-01 |  |  |  |
| 86 | 1.3.1.5 | Outer layers design |  | 633d | 2001-01-09 | 2003-06-12 | 93FF | 731d |  | start no earlier than 2000-10-02 |  |  |  |
| 87 | 1.3.1.6 | B-layer design |  | 390d | 2002-08-30 | 2004-02-26 | 100FF | 546d |  | start no earlier than 2000-10-02 |  |  |  |
| 88 | 1.3.1.7 | Test design |  | 418d | 2001-01-09 | 2002-08-15 | 91FF | 946d |  | start no earlier than 2000-10-02 |  |  |  |
| 89 | 1.3.1.8 | Management contingency decision DMILL | milestone | 0d | 1999-10-01 | 1999-10-01 |  | 1696d |  |  |  |  |  |
| 90 | 1.3.1.9 | FE-I2 spec complete | milestone | 0d | 2002-07-18 | 2002-07-18 | 91FF-20d | 966d |  |  |  |  |  |
| 91 | 1.3.1.10 | FE-I2 FDR | milestone | 0d | 2002-08-15 | 2002-08-15 | 117 | 201d | 0d | start no earlier than 2001-07-25 |  |  |  |
| 92 | 1.3.1.11 | IBM Production release order effort |  | 60d | 2003-03-21 | 2003-06-12 | 93FF | 731d |  |  |  |  |  |
| 93 | 1.3.1.12 | IBM FE PRR | milestone | 0d | 2003-06-12 | 2003-06-12 | 123 | 201d | 0d | start no earlier than 2002-10-15 |  |  |  |
| 94 | 1.3.1.13 | ATLAS PM approval of IBM procurement | milestone | 0d | 2003-06-19 | 2003-06-19 | 93FS+5d | 201d | 0d | start no earlier than 2002-04-22 |  |  |  |
| 95 | 1.3.1.14 | Release initial MC for IBM FE | milestone | 0d | 2003-06-19 | 2003-06-19 | 94 | 201d | 0d |  |  |  |  |
| 96 | 1.3.1.15 | Release IBM production | milestone | 0d | 2003-06-19 | 2003-06-19 | 95 | 201d | 0d |  |  |  |  |
| 97 | 1.3.1.16 | B-Layer FDR | milestone | 0d | 2003-06-12 | 2003-06-12 | 93 | 731d |  | start no earlier than 2002-11-15 |  |  |  |
| 98 | 1.3.1.17 | Compl. Spec for B-Layer prod order release | milestone | 0d | 2003-09-12 | 2003-09-12 | 99SS-30d | 666d |  |  |  |  |  |
| 99 | 1.3.1.18 | Production release order effort |  | 90d | 2003-10-24 | 2004-02-26 | 100FF | 546d | 0d |  |  |  |  |
| 100 | 1.3.1.19 | B-Layer PRR | milestone | 0d | 2004-02-26 | 2004-02-26 | 135SS+80d | 311d | 0d | start no earlier than 2002-06-04 |  |  |  |
| 101 | 1.3.1.20 | ATLAS PM Approval of B-Layer Proc. | milestone | 0d | 2004-03-04 | 2004-03-04 | 100FS+5d | 541d | 0d |  |  |  |  |
| 102 | 1.3.1.21 | Release initial MC for B-layer production | milestone | 0d | 2004-03-04 | 2004-03-04 | 101 | 541d | 0d |  |  |  |  |
| 103 | 1.3.1.22 | Release B-Layer Production | milestone | 0d | 2004-03-04 | 2004-03-04 | 102 | 541d |  |  |  |  |  |
| 104 | 1.3.1.23 | Optical IC design |  | 633d | 2001-01-09 | 2003-06-12 | 93FF | 731d |  | start no earlier than 2000-10-02 |  |  |  |
| 105 | 1.3.1.24 | Optical IC FDR | milestone | 0d | 2002-08-15 | 2002-08-15 | 91 | 946d |  |  |  |  |  |
| 106 | 1.3.1.25 | Optical IC PRR | milestone | 0d | 2003-06-12 | 2003-06-12 | 93 | 521d | 0d |  |  |  |  |
| 107 | 1.3.1.26 | Release initial MC for optical IC | milestone | 0d | 2003-06-19 | 2003-06-19 | 106FS+5d | 726d |  |  |  |  |  |

| ID | WBS | Task | Type | Duration | Start | Finish | Predecessors | Total slack | Free slack | Constraint | Resources | Work | Cost |
| --- | --- | --- | --- | --- | --- | --- | --- | --- | --- | --- | --- | --- | --- |
| 108 | 1.1.1.3.2 | **Development/Prototypes** |  | 724d | 2001-01-08 | 2003-10-16 |  | 435d |  |  |  |  | 367,136 |
| 109 | 1.3.2.1 | Elec.'s Develop/Protos FY01 $s |  | 190d | 2001-01-08 | 2001-09-28 |  | 1175d |  | start no earlier than 2001-01-08 | LBLj PM PRJ; LBLs PM PRJ; OSU LW PRJ; SUNYA PM PRJ |  | 234,053 |
| 110 | 1.3.2.2 | Elec.'s Develop/Protos FY02 $s |  | 261d | 2001-10-01 | 2002-09-30 |  | 914d |  | start no earlier than 2001-10-01 | LBLs HI PRJ; OSU HI PRJ |  | 133,083 |
| 111 | 1.3.2.3 | Elec.'s Develop/Protos FY03 $s |  | 261d | 2002-10-01 | 2003-09-30 |  | 653d |  | start no earlier than 2002-10-01 |  |  |  |
| 112 | 1.3.2.4 | Elec.'s Develop/Protos FY04 $s |  | 12d | 2003-10-01 | 2003-10-16 |  | 641d |  | start no earlier than 2003-10-01 |  |  |  |
| 113 | Sil L2/6 | 1st IBM prototype submitted(FE-I1) | milestone | 0d | 2001-11-30 | 2001-11-30 |  | 201d | 0d | start no earlier than 2001-11-30 |  |  |  |
| 114 | 1.3.2.6 | 1st IBM prototype delivered | milestone | 0d | 2002-01-31 | 2002-01-31 | 113FS+45d | 201d | 0d |  |  |  |  |
| 115 | 1.3.2.7 | Complete initial wafer probe FE-I1 | milestone | 0d | 2002-02-14 | 2002-02-14 | 114FS+10d | 201d | 0d |  |  |  |  |
| 116 | 1.3.2.8 | First bump bonded FE-I1 assemblies arrive | milestone | 0d | 2002-04-18 | 2002-04-18 | 115FS+45d | 891d | 0d |  |  |  |  |
| 117 | 1.3.2.9 | Complete initial lab/ irradiation tests FE-I1 | milestone | 0d | 2002-08-15 | 2002-08-15 | 115FS+130d | 201d | 0d |  |  |  |  |
| 118 | 1.3.2.10 | Beam/system tests of FE-I1 assemblies |  | 140d | 2002-04-19 | 2002-10-31 | 116 | 891d |  | start no earlier than 2002-03-01 |  |  |  |
| 119 | 1.3.2.11 | 2nd IBM prototype submitted(FE-I2) | milestone | 0d | 2002-09-26 | 2002-09-26 | 91FS+30d | 201d | 0d | start no earlier than 2001-10-14 |  |  |  |
| 120 | 1.3.2.12 | 2nd IBM prototype wafers delivered | milestone | 0d | 2002-12-26 | 2002-12-26 | 119FS+65d | 201d | 0d |  |  |  |  |
| 121 | 1.3.2.13 | Complete initial wafer probe FE-I2 | milestone | 0d | 2003-02-06 | 2003-02-06 | 120FS+30d | 821d |  |  |  |  |  |
| 122 | 1.3.2.14 | First bump bonded FE-I2assemblies arrive | milestone | 0d | 2003-03-06 | 2003-03-06 | 120SS+50d | 641d | 0d |  |  |  |  |
| 123 | 1.3.2.15 | Complete initial lab/system/ irradiation tests FE-I2 | milestone | 0d | 2003-06-12 | 2003-06-12 | 120FS+120d | 201d | 0d |  |  |  |  |
| 124 | 1.3.2.16 | Beam/system tests of FE-I2 assemblies |  | 160d | 2003-03-07 | 2003-10-16 | 122 | 641d |  | start no earlier than 2003-01-10 |  |  |  |
| 125 | 1.1.1.3.3 | **Production** |  | 669d | 2002-04-01 | 2004-10-21 |  | 376d |  |  |  | 2940h | 260,717.4 |
| 126 | 1.3.3.1 | Elec.'s Production FY02 $s |  | 131d | 2002-04-01 | 2002-09-30 |  | 914d |  | start no earlier than 2002-04-01 | LBLs PM PRJ; OSU LW PRJ |  | 41,821 |
| 127 | 1.3.3.2 | Elec.'s Production FY03 $s |  | 261d | 2002-10-01 | 2003-09-30 |  | 653d |  | start no earlier than 2002-10-01 | LBLs CL PRJ [84.3%]; LBLs HI PRJ; LBLs PM PRJ; OSU HI PRJ; OSU LW PRJ; OSU ST PRJ [14.4%] | 2060h | 192,805.6 |
| 128 | 1.3.3.3 | Elec.'s Production FY04 $s |  | 206d | 2003-10-01 | 2004-07-14 |  | 447d |  | start no earlier than 2003-10-01 | LBLs CL PRJ [53.4%]; LBLs PM PRJ | 880h | 26,090.8 |
| 129 | Sil L2/7 | Start IBM Production | milestone | 0d | 2003-06-12 | 2003-06-12 | 123 | 731d |  | start no earlier than 2003-03-13 |  |  |  |
| 130 | 1.3.3.5 | Outer FE IBM Production |  | 250d | 2003-06-20 | 2004-06-03 | 96 | 201d | 0d | start no earlier than 2001-09-03 |  |  |  |
| 131 | 1.3.3.6 | 1st outer IBM wafers arrive | milestone | 0d | 2003-11-06 | 2003-11-06 | 130SS+100d | 201d | 0d |  |  |  |  |
| 132 | 1.3.3.7 | 10% outer wafers complete | milestone | 0d | 2003-11-06 | 2003-11-06 | 131 | 626d |  |  |  |  |  |
| 133 | 1.3.3.8 | 25% outer wafers complete | milestone | 0d | 2003-12-15 | 2003-12-15 |  | 600d |  | start no earlier than 2003-12-15 |  |  |  |
| 134 | 1.3.3.9 | 50% outer wafers complete | milestone | 0d | 2004-03-15 | 2004-03-15 |  | 535d |  | start no earlier than 2004-03-15 |  |  |  |
| 135 | 1.3.3.10 | Test outer FE IBM wafers |  | 250d | 2003-11-07 | 2004-10-21 | 131 | 201d | 0d |  |  |  |  |
| 136 | 1.3.3.11 | Outer IBM FE Testing complete | milestone | 0d | 2004-10-21 | 2004-10-21 | 135 | 376d |  |  |  |  |  |
| 137 | 1.3.3.12 | B-Layer FE Production |  | 120d | 2004-02-27 | 2004-08-12 | 100 | 311d | 0d |  |  |  |  |
| 138 | 1.3.3.13 | 1st B-Layer wafers arrive | milestone | 0d | 2004-07-15 | 2004-07-15 | 137SS+100d | 311d | 0d |  |  |  |  |
| 139 | 1.3.3.14 | Test B-layer wafers |  | 50d | 2004-07-16 | 2004-09-23 | 138 | 311d | 0d |  |  |  |  |
| 140 | 1.3.3.15 | B-Layer testing complete | milestone | 0d | 2004-09-23 | 2004-09-23 | 139 | 396d |  |  |  |  |  |
| 141 | 1.3.3.16 | Optical IC production |  | 100d | 2003-08-08 | 2003-12-25 | 106FS+40d | 546d | 0d |  |  |  |  |
| 142 | 1.3.3.17 | 1st Production Optical ICs | milestone | 0d | 2003-12-04 | 2003-12-04 | 141SS+85d | 546d | 0d |  |  |  |  |
| 143 | 1.3.3.18 | Test optical Ics |  | 60d | 2003-12-05 | 2004-02-26 | 142 | 546d | 0d |  |  |  |  |
| 144 | 1.3.3.19 | Optical IC testing complete | milestone | 0d | 2004-02-26 | 2004-02-26 | 143 | 546d |  |  |  |  |  |

Notes:
- 130: Assumes Temic. 265 wafers required.
- 135: About 4 wafers per day all sites.

| ID | WBS | Task | Type | Duration | Start | Finish | Predecessors | Total slack | Free slack | Constraint | Resources | Work | Cost |
| --- | --- | --- | --- | --- | --- | --- | --- | --- | --- | --- | --- | --- | --- |
| 146 | 1.1.1.4 | **Flex Hybrids/Optical Hybrids** |  | 1059d | 2000-10-02 | 2004-10-22 |  | 376d |  |  |  | 7900h | 524,984.5 |
| 147 | 1.1.1.4.1 | **Design** |  | 714d | 2000-10-02 | 2003-06-26 |  | 721d |  |  |  | 3080h | 77,366 |
| 148 | 1.4.1.1 | Hybrids Design FY01 $s |  | 260d | 2000-10-02 | 2001-09-28 |  | 1175d |  | start no earlier than 2000-10-02 | UOK ST PRJ [42.3%]; UOK TR PRJ | 880h | 18,461.2 |
| 149 | 1.4.1.2 | Hybrids Design FY02 $s |  | 261d | 2001-10-01 | 2002-09-30 |  | 914d |  | start no earlier than 2001-10-01 | LBLs DS PRJ [21.1%]; UOK ST PRJ [84.3%]; UOK TR PRJ | 2200h | 50,114.8 |
| 150 | 1.4.1.3 | Hybrids Design FY03 $s |  | 122d | 2002-10-01 | 2003-03-19 |  | 792d |  | start no earlier than 2002-10-01 | UOK TR PRJ |  | 8,790 |
| 151 | 1.4.1.4 | Flex Preproduction Design |  | 120d | 2002-04-26 | 2002-10-10 | 114FS+60d | 496d | 0d | start no earlier than 2001-12-31 |  |  |  |
| 152 | 1.4.1.5 | Release Flex Bids | milestone | 0d | 2002-08-01 | 2002-08-01 | 153FF-30d | 956d |  |  |  |  |  |
| 153 | 1.4.1.6 | Flex Bid Evaluation Complete | milestone | 0d | 2002-09-12 | 2002-09-12 | 154FF-20d | 926d | 0d |  |  |  |  |
| 154 | 1.4.1.7 | Flex Hybrid PRR | milestone | 0d | 2002-10-10 | 2002-10-10 | 151 | 496d | 0d | start no earlier than 1999-10-01 |  |  |  |
| 155 | 1.4.1.8 | ATLAS PM Approval of Flex Proc | milestone | 0d | 2002-10-24 | 2002-10-24 | 154FS+10d | 496d | 0d |  |  |  |  |
| 156 | 1.4.1.9 | Release initial MC for flex hybrid and assembly | milestone | 0d | 2002-10-24 | 2002-10-24 | 155 | 896d |  |  |  |  |  |
| 157 | 1.4.1.10 | Award Flex Contracts | milestone | 0d | 2002-11-07 | 2002-11-07 | 155FS+10d | 496d | 0d |  |  |  |  |
| 158 | 1.4.1.11 | Optical FDR | milestone | 0d | 2002-10-10 | 2002-10-10 | 154 | 906d |  |  |  |  |  |
| 159 | 1.4.1.12 | Optical PRR | milestone | 0d | 2003-06-12 | 2003-06-12 | 106 | 521d | 0d | start no earlier than 2002-02-15 |  |  |  |
| 160 | 1.4.1.13 | Release initial MC for optical components | milestone | 0d | 2003-06-26 | 2003-06-26 | 159FS+10d | 721d |  |  |  |  |  |
| 161 | 1.1.1.4.2 | **Development Prototypes** |  | 624d | 2001-01-08 | 2003-05-29 |  | 741d |  | start no earlier than 2000-07-18 |  | 1300h | 153,624 |
| 162 | 1.4.2.1 | Hybrids Protos FY01 $s |  | 190d | 2001-01-08 | 2001-09-28 |  | 1175d |  | start no earlier than 2001-01-08 | LBLs CL PRJ [6.6%]; LBLs SH PRJ [1.3%]; LBLs PM PRJ; UOK ST PRJ [28.9%]; UOK LW PRJ; OSU ST PRJ [6.6%]; OSU LW PRJ | 660h | 91,517.4 |
| 163 | 1.4.2.2 | Hybrids Protos FY02 $s |  | 261d | 2001-10-01 | 2002-09-30 |  | 914d |  | start no earlier than 2001-10-01 | LBLs CL PRJ [4.8%]; LBLs PM PRJ; UOK ST PRJ [21.1%]; UOK LW PRJ; OSU ST PRJ [4.8%]; OSU LW PRJ | 640h | 62,106.6 |
| 164 | 1.4.2.3 | Hybrids Protos Fy03 $s |  | 13d | 2002-10-01 | 2002-10-17 |  | 901d |  | start no earlier than 2002-10-01 |  |  |  |
| 165 | 1.4.2.4 | Flex 3.x,4.x Fab and Test |  | 380d | 2001-10-01 | 2003-03-14 |  | 795d | 0d | start no earlier than 2001-10-01 |  |  |  |
| 166 | 1.4.2.5 | Initial Flex 3.x4.x tests complete | milestone | 0d | 2002-05-10 | 2002-05-10 | 165SS+160d | 1015d | 0d |  |  |  |  |
| 167 | 1.4.2.6 | 2nd Optical Prototype Fab and Test |  | 220d | 2001-10-01 | 2002-08-02 |  | 955d |  | start no earlier than 2001-10-01 |  |  |  |
| 168 | 1.4.2.7 | 3rd Optical Prototype Fab and Test |  | 150d | 2002-11-01 | 2003-05-29 | 159SS-160d | 741d |  |  |  |  |  |
| 169 | 1.1.1.4.3 | **Production** |  | 746d | 2001-12-13 | 2004-10-22 |  | 376d |  |  |  | 3520h | 293,994.5 |
| 170 | 1.4.3.1 | Hybrids Production FY02 $s |  | 208d | 2001-12-13 | 2002-09-30 |  | 914d |  | start no earlier than 2001-12-13 | SUNYA PM PRJ; UOK LW PRJ; OSU LW PRJ |  | 26,000 |
| 171 | 1.4.3.2 | Hybrids Production FY03 $s |  | 261d | 2002-10-01 | 2003-09-30 |  | 653d |  | start no earlier than 2002-10-01 | LBLs CL PRJ [13%]; LBLs PM PRJ; SUNYA ST PRJ [33.6%]; UOK ST PRJ [33.6%]; UOK ET PRJ [9.6%]; UOK HI PRJ; UOK LW PRJ; OSU ET PRJ [59.4%]; OSU ST PRJ [13.4%]; OSU LW PRJ | 3396h | 264,033.5 |
| 172 | 1.4.3.3 | Hybrids Production FY04 $s |  | 207d | 2003-10-01 | 2004-07-15 |  | 446d |  | start no earlier than 2003-10-01 | UOK ET PRJ [1.4%]; OSU ET PRJ [4.8%]; OSU ST PRJ [1.2%] | 124h | 3,961 |
| 173 | 1.4.3.4 | Start initial production buy of components | milestone | 0d | 2002-05-10 | 2002-05-10 | 166 | 1015d |  | start no earlier than 1999-10-01 |  |  |  |
| 174 | 1.4.3.5 | Outer Flex Hybrid (Pre)Production/Load |  | 250d | 2002-11-08 | 2003-10-23 | 157 | 496d | 0d |  |  |  |  |
| 175 | 1.4.3.6 | First outer flex delivered | milestone | 0d | 2003-02-27 | 2003-02-27 | 174SS+80d | 496d | 0d |  |  |  |  |
| 176 | 1.4.3.7 | 10% outer flex complete | milestone | 0d | 2003-04-01 | 2003-04-01 |  | 784d |  | start no earlier than 2003-04-01 |  |  |  |
| 177 | 1.4.3.8 | 25% outer flex complete | milestone | 0d | 2003-05-15 | 2003-05-15 |  | 752d |  | start no earlier than 2003-05-15 |  |  |  |
| 178 | 1.4.3.9 | 50% outer flex complete | milestone | 0d | 2003-07-15 | 2003-07-15 |  | 709d |  | start no earlier than 2003-07-15 |  |  |  |
| 179 | 1.4.3.10 | Outer flex testing |  | 250d | 2003-02-28 | 2004-02-12 | 175 | 496d | 0d |  |  |  |  |
| 180 | 1.4.3.11 | First outer flex available for module assembly | milestone | 0d | 2003-05-22 | 2003-05-22 | 175FS+60d | 746d |  |  |  |  |  |
| 181 | 1.4.3.12 | Need date for first outer flex | milestone | 0d | 2004-02-27 | 2004-02-27 | 221SS-10d | 546d |  |  |  |  |  |
| 182 | 1.4.3.13 | Outer flex testing complete | milestone | 0d | 2004-02-12 | 2004-02-12 | 179 | 496d | 0d |  |  |  |  |
| 183 | 1.4.3.14 | B-Layer Flex Hybrid (Pre)Production/Load/Test |  | 90d | 2003-11-21 | 2004-03-25 | 182FS-60d | 496d | 0d |  |  |  |  |
| 184 | 1.4.3.15 | First B-Layer flex delivered | milestone | 0d | 2004-02-12 | 2004-02-12 | 183SS+60d | 496d | 0d |  |  |  |  |
| 185 | 1.4.3.16 | First B-Layer flex available for modules | milestone | 0d | 2004-05-06 | 2004-05-06 | 184FS+60d | 496d |  |  |  |  |  |
| 186 | 1.4.3.17 | Need date for first B-layer flex | milestone | 0d | 2004-10-22 | 2004-10-22 | 228SS-10d | 376d |  |  |  |  |  |
| 187 | 1.4.3.18 | B-Layer flex testing complete | milestone | 0d | 2004-03-25 | 2004-03-25 | 183 | 526d |  |  |  |  |  |
| 188 | 1.4.3.19 | Optical (Pre)Production |  | 190d | 2003-07-11 | 2004-04-01 | 159FS+20d | 521d | 0d |  |  |  |  |
| 189 | 1.4.3.20 | First optical boards | milestone | 0d | 2003-11-27 | 2003-11-27 | 188SS+100d | 611d |  |  |  |  |  |
| 190 | 1.4.3.21 | Optical production complete | milestone | 0d | 2004-04-01 | 2004-04-01 | 188 | 521d |  |  |  |  |  |

| ID | WBS | Task | Type | Duration | Start | Finish | Predecessors | Total slack | Free slack | Constraint | Resources | Work | Cost |
| --- | --- | --- | --- | --- | --- | --- | --- | --- | --- | --- | --- | --- | --- |
| 192 | 1.1.1.5 | **Modules** |  | 926d | 2001-07-05 | 2005-01-20 |  | 311d |  |  |  | 20603h | 923,605.21 |
| 193 | 1.1.1.5.1 | **Design** |  | 646d | 2001-07-26 | 2004-01-16 |  | 576d |  |  |  | 2200h | 126,191.6 |
| 194 | 1.5.1.1 | Modules Design FY01 $s |  | 47d | 2001-07-26 | 2001-09-28 |  | 1175d |  | start no earlier than 2001-07-26 | LBLj DS PRJ [117%]; LBLj EE PRJ [234%]; LBLj TR PRJ | 1320h | 78,704.8 |
| 195 | 1.5.1.2 | Modules Design FY02 $s |  | 261d | 2001-10-01 | 2002-09-30 |  | 914d |  | start no earlier than 2001-10-01 | LBLj DS PRJ [21.1%]; LBLj EE PRJ [21.1%]; LBLj TR PRJ | 880h | 47,486.8 |
| 196 | 1.5.1.3 | Modules Design FY03 $s |  | 212d | 2002-10-01 | 2003-07-23 |  | 702d |  | start no earlier than 2002-10-01 |  |  |  |
| 197 | 1.5.1.4 | Prototype tooling/assembly design |  | 240d | 2001-11-09 | 2002-10-10 | 198FF | 906d |  | start no earlier than 2000-10-02 |  |  |  |
| 198 | 1.5.1.5 | Bare module PRR | milestone | 0d | 2002-10-10 | 2002-10-10 | 91FS+40d | 906d | 0d | start no earlier than 2001-08-31 |  |  |  |
| 199 | 1.5.1.6 | Module assembly FDR | milestone | 0d | 2002-10-10 | 2002-10-10 | 198 | 906d |  |  |  |  |  |
| 200 | 1.5.1.7 | Production tooling/assembly design |  | 138d | 2003-02-25 | 2003-09-04 | 201FF | 671d |  |  |  |  |  |
| 201 | 1.5.1.8 | Module assembly PRR | milestone | 0d | 2003-09-04 | 2003-09-04 | 93FS+60d | 631d | 0d |  |  |  |  |
| 202 | 1.5.1.9 | Release initial MC for FE die sort | milestone | 0d | 2003-10-02 | 2003-10-02 | 201FS+20d | 651d |  |  |  |  |  |
| 203 | 1.5.1.10 | Production module tooling complete | milestone | 0d | 2003-10-30 | 2003-10-30 | 201FS+40d | 631d |  |  |  |  |  |
| 204 | 1.5.1.11 | Need date for production module tooling | milestone | 0d | 2004-01-16 | 2004-01-16 | 221SS-40d | 576d |  |  |  |  |  |
| 205 | 1.1.1.5.2 | **Development/Prototypes** |  | 566d | 2001-07-05 | 2003-09-04 |  | 671d |  |  |  | 4156h | 261,240 |
| 206 | 1.5.2.1 | Modules Protos FY01 $s |  | 62d | 2001-07-05 | 2001-09-28 |  | 1175d |  | start no earlier than 2001-07-05 | LBLj MT PRJ [26.6%]; LBLj TS PRJ [18.1%]; LBLj PM PRJ; LBLj S PRJ; LBLs PM PRJ | 222h | 80,538.24 |
| 207 | 1.5.2.2 | Modules Protos FY02 $s |  | 261d | 2001-10-01 | 2002-09-30 |  | 914d |  | start no earlier than 2001-10-01 | LBLj ET PRJ [21.1%]; LBLj MT PRJ [25.3%]; LBLj SH PRJ [50.4%]; LBLj TS PRJ [4.3%]; LBLj PM PRJ; LBLj S PRJ; LBLs ST PRJ [3.6%]; LBLs SH PRJ [1%]; LBLs PM PRJ | 2206h | 134,647 |
| 208 | 1.5.2.3 | Modules Protos FY03 $s |  | 172d | 2002-10-01 | 2003-05-28 |  | 742d |  | start no earlier than 2002-10-01 | LBLj ET PRJ [16%]; LBLj MT PRJ [38.4%]; LBLj ST PRJ [64%]; LBLj S PRJ; LBLs ST PRJ [7.3%]; LBLs PM PRJ | 1728h | 46,054.76 |
| 209 | 1.5.2.4 | Dummy/prototype module fab/test |  | 495d | 2001-10-12 | 2003-09-04 | 201FF | 671d |  | start no earlier than 2000-10-02 |  |  |  |
| 210 | 1.1.1.5.3 | **Production** |  | 366d | 2003-08-28 | 2005-01-20 |  | 272d |  |  |  | 14247h | 536,173.61 |
| 211 | 1.5.3.1 | Modules Production FY03 $s |  | 24d | 2003-08-28 | 2003-09-30 |  | 653d |  | start no earlier than 2003-08-28 | LBLj ST PRJ [1947.9%]; LBLj PM PRJ; LBLs CL PRJ [916.7%]; LBLs ET PRJ [93.8%]; LBLs MT PRJ [93.8%]; LBLs SH PRJ [156.8%]; LBLs ST PRJ [916.7%]; LBLs PM PRJ; OSU CL PRJ [306.8%]; OSU MT PRJ [306.8%]; OSU LW PRJ | 9099h | 345,935.98 |
| 212 | 1.5.3.2 | Modules Production FY04 $s |  | 262d | 2003-10-01 | 2004-09-30 |  | 391d |  | start no earlier than 2003-10-01 | LBLj ST PRJ [94.5%]; LBLj PM PRJ; LBLs CL PRJ [28.1%]; LBLs ET PRJ [33.4%]; LBLs MT PRJ [33.4%]; LBLs ST PRJ [28.1%]; LBLs PM PRJ; OSU CL PRJ [14.1%]; OSU MT PRJ [14.1%]; OSU LW PRJ | 5148h | 190,237.63 |
| 213 | 1.5.3.3 | Modules Production FY05 $s |  | 9d | 2004-10-01 | 2004-10-13 |  | 382d |  | start no earlier than 2004-10-01 |  |  |  |
| 214 | 1.5.3.4 | IBM FE Bump Deposition |  | 230d | 2003-12-05 | 2004-10-21 | 135SS+20d | 201d | 0d |  |  |  |  |
| 215 | 1.5.3.5 | IBM FE wafer thinning |  | 230d | 2004-01-02 | 2004-11-18 | 214SS+20d | 201d | 0d |  |  |  |  |
| 216 | 1.5.3.6 | IBM FE Wafer Dicing |  | 230d | 2004-01-09 | 2004-11-25 | 215SS+5d | 201d | 0d |  |  |  |  |
| 217 | 1.5.3.7 | IBM FE Die sort |  | 230d | 2004-01-16 | 2004-12-02 | 216SS+5d | 201d | 0d |  |  |  |  |
| 218 | Sil L2/8 | Start IBM outer bare module production | milestone | 0d | 2004-01-29 | 2004-01-29 | 217SS+10d | 201d | 0d |  |  |  |  |
| 219 | 1.5.3.9 | IBM Outer bare module production |  | 180d | 2004-01-30 | 2004-10-07 | 218 | 201d | 0d |  |  |  |  |
| 220 | 1.5.3.10 | IBM outer bare module testing |  | 165d | 2004-02-27 | 2004-10-14 | 219SS+20d | 201d | 0d |  |  |  |  |
| 221 | 1.5.3.11 | IBM outer module assembly/test |  | 165d | 2004-03-12 | 2004-10-28 | 220SS+10d | 201d | 0d |  |  |  |  |
| 222 | 1.5.3.12 | Complete testing IBM outer modules | milestone | 0d | 2004-10-28 | 2004-10-28 | 221 | 371d |  |  |  |  |  |
| 223 | 1.5.3.13 | Module attach to disk sectors |  | 160d | 2004-03-26 | 2004-11-04 | 37SS+120d, 221SS+10d | 201d | 0d |  |  |  |  |
| 224 | 1.5.3.14 | Test disk sectors |  | 160d | 2004-04-02 | 2004-11-11 | 223SS+5d | 201d | 0d |  |  |  |  |
| 225 | 1.5.3.15 | Complete testing disk sectors | milestone | 0d | 2004-11-11 | 2004-11-11 | 224 | 361d |  |  |  |  |  |
| 226 | 1.5.3.16 | Start B-Layer bare module production | milestone | 0d | 2004-10-21 | 2004-10-21 | 139SS+70d | 311d | 0d |  |  |  |  |
| 227 | 1.5.3.17 | B-Layer bare module production |  | 55d | 2004-10-22 | 2005-01-06 | 226 | 311d | 0d |  |  |  |  |
| 228 | 1.5.3.18 | B-Layer module assembly/test |  | 55d | 2004-11-05 | 2005-01-20 | 227SS+10d | 311d | 0d | start no earlier than 2003-10-20 |  |  |  |
| 229 | 1.5.3.19 | Complete testing B-Layer modules | milestone | 0d | 2005-01-20 | 2005-01-20 | 228 | 311d |  |  |  |  |  |

Notes:
- 214: Includes B-layer
- 215: Includes B-layer
- 216: Includes B-layer
- 217: Includes B-layer
- 219: About 35 modules per week. Peak rate from two vendors is expected to be 40 modules per week.
- 220: About 35 modules per week.
- 221: About 35 modules per week.
- 223: About one sector every four days. This is about 1/2 of expected rate.
- 224: About one sector every four days. This is about 1/2 of expected rate.
- 227: About 35 modules per week. Peak rate from two vendors is expected to be 40 modules per week.
- 228: About 35 modules per week. Peak rate from two vendors is expected to be 40 modules per week.

| ID | WBS | Task | Duration | Start | Finish | Total slack | Constraint | Resources | Cost |
| --- | --- | --- | --- | --- | --- | --- | --- | --- | --- |
| 231 | 1.1.1.6 | **Beam/System Test Support** | 1305d | 2000-10-02 | 2005-09-30 | 130d |  |  | 116,865 |
| 232 | 1.6.1 | **Test Beam Support** | 780d | 2000-10-02 | 2003-09-26 | 655d |  |  | 44,520 |
| 233 | 1.6.1.1 | Test Beam Support FY01 $s | 260d | 2000-10-02 | 2001-09-28 | 1175d | start no earlier than 2000-10-02 | LBLj PM PRJ | 11,130 |
| 234 | 1.6.1.2 | Test Beam Support FY02 $s | 261d | 2001-10-01 | 2002-09-30 | 914d | start no earlier than 2001-10-01 | LBLj PM PRJ | 16,695 |
| 235 | 1.6.1.3 | Test Beam Support FY03 $s | 259d | 2002-10-01 | 2003-09-26 | 655d | start no earlier than 2002-10-01 | LBLj PM PRJ | 16,695 |
| 236 | 1.6.2 | **System Test Support** | 1305d | 2000-10-02 | 2005-09-30 | 130d |  |  | 72,345 |
| 237 | 1.6.2.1 | System Test Support FY01 $s | 260d | 2000-10-02 | 2001-09-28 | 1175d | start no earlier than 2000-10-02 | LBLj PM PRJ | 16,695 |
| 238 | 1.6.2.2 | System Test Support FY02 $s | 261d | 2001-10-01 | 2002-09-30 | 914d | start no earlier than 2001-10-01 | LBLj PM PRJ | 16,695 |
| 239 | 1.6.2.3 | System Test Support FY03 $s | 261d | 2002-10-01 | 2003-09-30 | 653d | start no earlier than 2002-10-01 | LBLj PM PRJ | 16,695 |
| 240 | 1.6.2.4 | System Test Support FY04$s | 262d | 2003-10-01 | 2004-09-30 | 391d | start no earlier than 2003-10-01 | LBLj PM PRJ | 11,130 |
| 241 | 1.6.2.5 | System Test Support FY05 $s | 261d | 2004-10-01 | 2005-09-30 | 130d | start no earlier than 2004-10-01 | LBLj PM PRJ | 11,130 |
